# Beispielprojekt

Schedule from MS Project, 2021-09-13 to 2022-01-28, A marks actual dates.

## Calendars

- Standard: Mon-Fri 08:00-12:00, 13:00-17:00; Sat-Sun off.

## Resources

| Resource |
| --- |
| Elektro |
| Putz |
| HLS |
| Trockenbau |
| Estrich |
| Bodenleger |
| Türen |
| Maler |
| Reinigung |

## Schedule

| ID | WBS | Task | Duration | Start | Finish | Predecessors | Complete | Remaining | Total slack | Free slack | Constraint | Resources | Work | Actual work | Text22 |
| --- | --- | --- | --- | --- | --- | --- | --- | --- | --- | --- | --- | --- | --- | --- | --- |
| 1 | 1 | **Gebäude A** | 100d | 2021-09-13 A | 2022-01-28 |  | 5% | 95d | 0d |  |  |  | 3000h | 150h |  |
| 2 | 1.1 | **EG** | 80d | 2021-09-13 A | 2021-12-31 |  | 23% | 61.33d | 20d |  |  |  | 600h | 140h |  |
| 3 | 1.1.1 | **Wohnung** | 80d | 2021-09-13 A | 2021-12-31 |  | 23% | 61.33d | 20d |  |  |  | 600h | 140h |  |
| 4 | 1.1.1.1 | Unterputz ELT | 5d | 2021-09-13 A | 2021-09-17 A |  | 100% |  |  |  | start no earlier than 2021-09-13 | Elektro | 40h | 40h | Geb.A - EG - Whg |
| 5 | 1.1.1.2 | Verputzen | 5d | 2021-09-20 A | 2021-09-24 A | 4 | 100% |  |  |  |  | Putz | 40h | 40h | Geb.A - EG - Whg |
| 6 | 1.1.1.3 | Steigleitung ELT | 10d | 2021-09-27 A | 2021-10-08 | 5 | 25% | 7.5d | 80d |  |  | Elektro | 80h | 20h | Geb.A - EG - Whg |
| 7 | 1.1.1.4 | Steigleitung HSL | 10d | 2021-09-27 A | 2021-10-08 | 5 | 50% | 5d | 40d | 20d |  | HLS | 80h | 40h | Geb.A - EG - Whg |
| 8 | 1.1.1.5 | TBW | 5d | 2021-11-08 | 2021-11-12 | 7 |  |  | 20d | 0d | start no earlier than 2021-11-08 | Trockenbau | 40h |  | Geb.A - EG - Whg |
| 9 | 1.1.1.6 | Estrich | 5d | 2021-11-15 | 2021-11-19 | 8 |  |  | 20d | 0d |  | Estrich | 40h |  | Geb.A - EG - Whg |
| 10 | 1.1.1.7 | Naturstein | 5d | 2021-11-22 | 2021-11-26 | 9 |  |  | 20d | 0d |  | Bodenleger | 40h |  | Geb.A - EG - Whg |
| 11 | 1.1.1.8 | Alutüren | 5d | 2021-11-29 | 2021-12-03 | 10 |  |  | 20d | 0d |  | Türen | 40h |  | Geb.A - EG - Whg |
| 12 | 1.1.1.9 | Maler | 5d | 2021-12-06 | 2021-12-10 | 11 |  |  | 20d | 0d |  | Maler | 40h |  | Geb.A - EG - Whg |
| 13 | 1.1.1.10 | Feininstallation ELT | 5d | 2021-12-13 | 2021-12-17 | 12 |  |  | 20d | 0d |  | Elektro | 40h |  | Geb.A - EG - Whg |
| 14 | 1.1.1.11 | Feininstallation HLS | 5d | 2021-12-13 | 2021-12-17 | 12 |  |  | 30d |  |  | HLS | 40h |  | Geb.A - EG - Whg |
| 15 | 1.1.1.12 | Feinreinigung | 5d | 2021-12-20 | 2021-12-24 | 13 |  |  | 20d | 0d |  | Reinigung | 40h |  | Geb.A - EG - Whg |
| 16 | 1.1.1.13 | Schließzylinder | 5d | 2021-12-27 | 2021-12-31 | 15 |  |  | 20d |  |  | Türen | 40h |  | Geb.A - EG - Whg |
| 17 | 1.2 | **1.OG** | 80d | 2021-09-20 A | 2022-01-07 |  | 2% | 78.67d | 15d |  |  |  | 600h | 10h |  |
| 18 | 1.2.1 | **Wohnung** | 80d | 2021-09-20 A | 2022-01-07 |  | 2% | 78.67d | 15d |  |  |  | 600h | 10h |  |
| 19 | 1.2.1.1 | Unterputz ELT | 5d | 2021-09-20 A | 2021-09-24 |  | 25% | 3.75d | 35d | 0d | start no earlier than 2021-09-20 | Elektro | 40h | 10h | Geb.A - 1.OG - Whg |
| 20 | 1.2.1.2 | Verputzen | 5d | 2021-09-27 | 2021-10-01 | 19 |  |  | 35d | 5d |  | Putz | 40h |  | Geb.A - 1.OG - Whg |
| 21 | 1.2.1.3 | Steigleitung ELT | 10d | 2021-10-11 | 2021-10-22 | 20 |  |  | 70d |  | start no earlier than 2021-10-11 | Elektro | 80h |  | Geb.A - 1.OG - Whg |
| 22 | 1.2.1.4 | Steigleitung HSL | 10d | 2021-10-11 | 2021-10-22 | 20 |  |  | 30d | 15d | start no earlier than 2021-10-11 | HLS | 80h |  | Geb.A - 1.OG - Whg |
| 23 | 1.2.1.5 | TBW | 5d | 2021-11-15 | 2021-11-19 | 22 |  |  | 15d | 0d | start no earlier than 2021-11-15 | Trockenbau | 40h |  | Geb.A - 1.OG - Whg |
| 24 | 1.2.1.6 | Estrich | 5d | 2021-11-22 | 2021-11-26 | 23 |  |  | 15d | 0d |  | Estrich | 40h |  | Geb.A - 1.OG - Whg |
| 25 | 1.2.1.7 | Naturstein | 5d | 2021-11-29 | 2021-12-03 | 24 |  |  | 15d | 0d |  | Bodenleger | 40h |  | Geb.A - 1.OG - Whg |
| 26 | 1.2.1.8 | Alutüren | 5d | 2021-12-06 | 2021-12-10 | 25 |  |  | 15d | 0d |  | Türen | 40h |  | Geb.A - 1.OG - Whg |
| 27 | 1.2.1.9 | Maler | 5d | 2021-12-13 | 2021-12-17 | 26 |  |  | 15d | 0d |  | Maler | 40h |  | Geb.A - 1.OG - Whg |
| 28 | 1.2.1.10 | Feininstallation ELT | 5d | 2021-12-20 | 2021-12-24 | 27 |  |  | 15d | 0d |  | Elektro | 40h |  | Geb.A - 1.OG - Whg |
| 29 | 1.2.1.11 | Feininstallation HLS | 5d | 2021-12-20 | 2021-12-24 | 27 |  |  | 25d |  |  | HLS | 40h |  | Geb.A - 1.OG - Whg |
| 30 | 1.2.1.12 | Feinreinigung | 5d | 2021-12-27 | 2021-12-31 | 28 |  |  | 15d | 0d |  | Reinigung | 40h |  | Geb.A - 1.OG - Whg |
| 31 | 1.2.1.13 | Schließzylinder | 5d | 2022-01-03 | 2022-01-07 | 30 |  |  | 15d |  |  | Türen | 40h |  | Geb.A - 1.OG - Whg |

| ID | WBS | Task | Duration | Start | Finish | Predecessors | Total slack | Free slack | Constraint | Resources | Work | Text22 |
| --- | --- | --- | --- | --- | --- | --- | --- | --- | --- | --- | --- | --- |
| 32 | 1.3 | **2.OG** | 80d | 2021-09-27 | 2022-01-14 |  | 10d |  |  |  | 600h |  |
| 33 | 1.3.1 | **Wohnung** | 80d | 2021-09-27 | 2022-01-14 |  | 10d |  |  |  | 600h |  |
| 34 | 1.3.1.1 | Unterputz ELT | 5d | 2021-09-27 | 2021-10-01 |  | 30d | 0d | start no earlier than 2021-09-27 | Elektro | 40h | Geb.A - 2.OG - Whg |
| 35 | 1.3.1.2 | Verputzen | 5d | 2021-10-04 | 2021-10-08 | 34 | 30d | 10d |  | Putz | 40h | Geb.A - 2.OG - Whg |
| 36 | 1.3.1.3 | Steigleitung ELT | 10d | 2021-10-25 | 2021-11-05 | 35 | 60d |  | start no earlier than 2021-10-25 | Elektro | 80h | Geb.A - 2.OG - Whg |
| 37 | 1.3.1.4 | Steigleitung HSL | 10d | 2021-10-25 | 2021-11-05 | 35 | 20d | 10d | start no earlier than 2021-10-25 | HLS | 80h | Geb.A - 2.OG - Whg |
| 38 | 1.3.1.5 | TBW | 5d | 2021-11-22 | 2021-11-26 | 37 | 10d | 0d | start no earlier than 2021-11-22 | Trockenbau | 40h | Geb.A - 2.OG - Whg |
| 39 | 1.3.1.6 | Estrich | 5d | 2021-11-29 | 2021-12-03 | 38 | 10d | 0d |  | Estrich | 40h | Geb.A - 2.OG - Whg |
| 40 | 1.3.1.7 | Naturstein | 5d | 2021-12-06 | 2021-12-10 | 39 | 10d | 0d |  | Bodenleger | 40h | Geb.A - 2.OG - Whg |
| 41 | 1.3.1.8 | Alutüren | 5d | 2021-12-13 | 2021-12-17 | 40 | 10d | 0d |  | Türen | 40h | Geb.A - 2.OG - Whg |
| 42 | 1.3.1.9 | Maler | 5d | 2021-12-20 | 2021-12-24 | 41 | 10d | 0d |  | Maler | 40h | Geb.A - 2.OG - Whg |
| 43 | 1.3.1.10 | Feininstallation ELT | 5d | 2021-12-27 | 2021-12-31 | 42 | 10d | 0d |  | Elektro | 40h | Geb.A - 2.OG - Whg |
| 44 | 1.3.1.11 | Feininstallation HLS | 5d | 2021-12-27 | 2021-12-31 | 42 | 20d |  |  | HLS | 40h | Geb.A - 2.OG - Whg |
| 45 | 1.3.1.12 | Feinreinigung | 5d | 2022-01-03 | 2022-01-07 | 43 | 10d | 0d |  | Reinigung | 40h | Geb.A - 2.OG - Whg |
| 46 | 1.3.1.13 | Schließzylinder | 5d | 2022-01-10 | 2022-01-14 | 45 | 10d |  |  | Türen | 40h | Geb.A - 2.OG - Whg |
| 47 | 1.4 | **3.OG** | 80d | 2021-10-04 | 2022-01-21 |  | 5d |  |  |  | 600h |  |
| 48 | 1.4.1 | **Wohnung** | 80d | 2021-10-04 | 2022-01-21 |  | 5d |  |  |  | 600h |  |
| 49 | 1.4.1.1 | Unterputz ELT | 5d | 2021-10-04 | 2021-10-08 |  | 25d | 0d | start no earlier than 2021-10-04 | Elektro | 40h | Geb.A - 3.OG - Whg |
| 50 | 1.4.1.2 | Verputzen | 5d | 2021-10-11 | 2021-10-15 | 49 | 25d | 15d |  | Putz | 40h | Geb.A - 3.OG - Whg |
| 51 | 1.4.1.3 | Steigleitung ELT | 10d | 2021-11-08 | 2021-11-19 | 50 | 50d |  | start no earlier than 2021-11-08 | Elektro | 80h | Geb.A - 3.OG - Whg |
| 52 | 1.4.1.4 | Steigleitung HSL | 10d | 2021-11-08 | 2021-11-19 | 50 | 10d | 5d | start no earlier than 2021-11-08 | HLS | 80h | Geb.A - 3.OG - Whg |
| 53 | 1.4.1.5 | TBW | 5d | 2021-11-29 | 2021-12-03 | 52 | 5d | 0d | start no earlier than 2021-11-29 | Trockenbau | 40h | Geb.A - 3.OG - Whg |
| 54 | 1.4.1.6 | Estrich | 5d | 2021-12-06 | 2021-12-10 | 53 | 5d | 0d |  | Estrich | 40h | Geb.A - 3.OG - Whg |
| 55 | 1.4.1.7 | Naturstein | 5d | 2021-12-13 | 2021-12-17 | 54 | 5d | 0d |  | Bodenleger | 40h | Geb.A - 3.OG - Whg |
| 56 | 1.4.1.8 | Alutüren | 5d | 2021-12-20 | 2021-12-24 | 55 | 5d | 0d |  | Türen | 40h | Geb.A - 3.OG - Whg |
| 57 | 1.4.1.9 | Maler | 5d | 2021-12-27 | 2021-12-31 | 56 | 5d | 0d |  | Maler | 40h | Geb.A - 3.OG - Whg |
| 58 | 1.4.1.10 | Feininstallation ELT | 5d | 2022-01-03 | 2022-01-07 | 57 | 5d | 0d |  | Elektro | 40h | Geb.A - 3.OG - Whg |
| 59 | 1.4.1.11 | Feininstallation HLS | 5d | 2022-01-03 | 2022-01-07 | 57 | 15d |  |  | HLS | 40h | Geb.A - 3.OG - Whg |
| 60 | 1.4.1.12 | Feinreinigung | 5d | 2022-01-10 | 2022-01-14 | 58 | 5d | 0d |  | Reinigung | 40h | Geb.A - 3.OG - Whg |
| 61 | 1.4.1.13 | Schließzylinder | 5d | 2022-01-17 | 2022-01-21 | 60 | 5d |  |  | Türen | 40h | Geb.A - 3.OG - Whg |

| ID | WBS | Task | Duration | Start | Finish | Predecessors | Complete | Remaining | Total slack | Free slack | Constraint | Resources | Work | Actual work | Text22 |
| --- | --- | --- | --- | --- | --- | --- | --- | --- | --- | --- | --- | --- | --- | --- | --- |
| 62 | 1.5 | **4.OG** | 80d | 2021-10-11 | 2022-01-28 |  |  |  | 0d |  |  |  | 600h |  |  |
| 63 | 1.5.1 | **Wohnung** | 80d | 2021-10-11 | 2022-01-28 |  |  |  | 0d |  |  |  | 600h |  |  |
| 64 | 1.5.1.1 | Unterputz ELT | 5d | 2021-10-11 | 2021-10-15 |  |  |  | 20d | 0d | start no earlier than 2021-10-11 | Elektro | 40h |  | Geb.A - 4.OG - Whg |
| 65 | 1.5.1.2 | Verputzen | 5d | 2021-10-18 | 2021-10-22 | 64 |  |  | 20d |  |  | Putz | 40h |  | Geb.A - 4.OG - Whg |
| 66 | 1.5.1.3 | Steigleitung ELT | 10d | 2021-11-22 | 2021-12-03 | 65 |  |  | 40d |  | start no earlier than 2021-11-22 | Elektro | 80h |  | Geb.A - 4.OG - Whg |
| 67 | 1.5.1.4 | Steigleitung HSL | 10d | 2021-11-22 | 2021-12-03 | 65 |  |  | 0d |  | start no earlier than 2021-11-22 | HLS | 80h |  | Geb.A - 4.OG - Whg |
| 68 | 1.5.1.5 | TBW | 5d | 2021-12-06 | 2021-12-10 | 67 |  |  | 0d |  |  | Trockenbau | 40h |  | Geb.A - 4.OG - Whg |
| 69 | 1.5.1.6 | Estrich | 5d | 2021-12-13 | 2021-12-17 | 68 |  |  | 0d |  |  | Estrich | 40h |  | Geb.A - 4.OG - Whg |
| 70 | 1.5.1.7 | Naturstein | 5d | 2021-12-20 | 2021-12-24 | 69 |  |  | 0d |  |  | Bodenleger | 40h |  | Geb.A - 4.OG - Whg |
| 71 | 1.5.1.8 | Alutüren | 5d | 2021-12-27 | 2021-12-31 | 70 |  |  | 0d |  |  | Türen | 40h |  | Geb.A - 4.OG - Whg |
| 72 | 1.5.1.9 | Maler | 5d | 2022-01-03 | 2022-01-07 | 71 |  |  | 0d |  |  | Maler | 40h |  | Geb.A - 4.OG - Whg |
| 73 | 1.5.1.10 | Feininstallation ELT | 5d | 2022-01-10 | 2022-01-14 | 72 |  |  | 0d |  |  | Elektro | 40h |  | Geb.A - 4.OG - Whg |
| 74 | 1.5.1.11 | Feininstallation HLS | 5d | 2022-01-10 | 2022-01-14 | 72 |  |  | 10d |  |  | HLS | 40h |  | Geb.A - 4.OG - Whg |
| 75 | 1.5.1.12 | Feinreinigung | 5d | 2022-01-17 | 2022-01-21 | 73 |  |  | 0d |  |  | Reinigung | 40h |  | Geb.A - 4.OG - Whg |
| 76 | 1.5.1.13 | Schließzylinder | 5d | 2022-01-24 | 2022-01-28 | 75 |  |  | 0d |  |  | Türen | 40h |  | Geb.A - 4.OG - Whg |
| 77 | 2 | **Gebäude B** | 100d | 2021-09-13 A | 2022-01-28 |  | 5% | 95d | 0d |  |  |  | 3000h | 150h |  |
| 78 | 2.1 | **EG** | 80d | 2021-09-13 A | 2021-12-31 |  | 17% | 66.67d | 20d |  |  |  | 600h | 100h |  |
| 79 | 2.1.1 | **Wohnung** | 80d | 2021-09-13 A | 2021-12-31 |  | 17% | 66.67d | 20d |  |  |  | 600h | 100h |  |
| 80 | 2.1.1.1 | Unterputz ELT | 5d | 2021-09-13 A | 2021-09-17 A |  | 100% |  |  |  | start no earlier than 2021-09-13 | Elektro | 40h | 40h | Geb.B - EG - Whg |
| 81 | 2.1.1.2 | Verputzen | 5d | 2021-09-20 A | 2021-09-24 A | 80 | 100% |  |  |  |  | Putz | 40h | 40h | Geb.B - EG - Whg |
| 82 | 2.1.1.3 | Steigleitung ELT | 10d | 2021-09-27 A | 2021-10-08 | 81 | 25% | 7.5d | 80d |  |  | Elektro | 80h | 20h | Geb.B - EG - Whg |
| 83 | 2.1.1.4 | Steigleitung HSL | 10d | 2021-09-27 | 2021-10-08 | 81 |  |  | 40d | 20d |  | HLS | 80h |  | Geb.B - EG - Whg |
| 84 | 2.1.1.5 | TBW | 5d | 2021-11-08 | 2021-11-12 | 83 |  |  | 20d | 0d | start no earlier than 2021-11-08 | Trockenbau | 40h |  | Geb.B - EG - Whg |
| 85 | 2.1.1.6 | Estrich | 5d | 2021-11-15 | 2021-11-19 | 84 |  |  | 20d | 0d |  | Estrich | 40h |  | Geb.B - EG - Whg |
| 86 | 2.1.1.7 | Naturstein | 5d | 2021-11-22 | 2021-11-26 | 85 |  |  | 20d | 0d |  | Bodenleger | 40h |  | Geb.B - EG - Whg |
| 87 | 2.1.1.8 | Alutüren | 5d | 2021-11-29 | 2021-12-03 | 86 |  |  | 20d | 0d |  | Türen | 40h |  | Geb.B - EG - Whg |
| 88 | 2.1.1.9 | Maler | 5d | 2021-12-06 | 2021-12-10 | 87 |  |  | 20d | 0d |  | Maler | 40h |  | Geb.B - EG - Whg |
| 89 | 2.1.1.10 | Feininstallation ELT | 5d | 2021-12-13 | 2021-12-17 | 88 |  |  | 20d | 0d |  | Elektro | 40h |  | Geb.B - EG - Whg |
| 90 | 2.1.1.11 | Feininstallation HLS | 5d | 2021-12-13 | 2021-12-17 | 88 |  |  | 30d |  |  | HLS | 40h |  | Geb.B - EG - Whg |
| 91 | 2.1.1.12 | Feinreinigung | 5d | 2021-12-20 | 2021-12-24 | 89 |  |  | 20d | 0d |  | Reinigung | 40h |  | Geb.B - EG - Whg |
| 92 | 2.1.1.13 | Schließzylinder | 5d | 2021-12-27 | 2021-12-31 | 91 |  |  | 20d |  |  | Türen | 40h |  | Geb.B - EG - Whg |

| ID | WBS | Task | Duration | Start | Finish | Predecessors | Complete | Remaining | Total slack | Free slack | Constraint | Resources | Work | Actual work | Text22 |
| --- | --- | --- | --- | --- | --- | --- | --- | --- | --- | --- | --- | --- | --- | --- | --- |
| 93 | 2.2 | **1.OG** | 80d | 2021-09-20 A | 2022-01-07 |  | 8% | 73.33d | 15d |  |  |  | 600h | 50h |  |
| 94 | 2.2.1 | **Wohnung** | 80d | 2021-09-20 A | 2022-01-07 |  | 8% | 73.33d | 15d |  |  |  | 600h | 50h |  |
| 95 | 2.2.1.1 | Unterputz ELT | 5d | 2021-09-20 A | 2021-09-24 A |  | 100% |  |  |  | start no earlier than 2021-09-20 | Elektro | 40h | 40h | Geb.B - 1.OG - Whg |
| 96 | 2.2.1.2 | Verputzen | 5d | 2021-09-27 A | 2021-10-01 | 95 | 25% | 3.75d | 35d | 5d |  | Putz | 40h | 10h | Geb.B - 1.OG - Whg |
| 97 | 2.2.1.3 | Steigleitung ELT | 10d | 2021-10-11 | 2021-10-22 | 96 |  |  | 70d |  | start no earlier than 2021-10-11 | Elektro | 80h |  | Geb.B - 1.OG - Whg |
| 98 | 2.2.1.4 | Steigleitung HSL | 10d | 2021-10-11 | 2021-10-22 | 96 |  |  | 30d | 15d | start no earlier than 2021-10-11 | HLS | 80h |  | Geb.B - 1.OG - Whg |
| 99 | 2.2.1.5 | TBW | 5d | 2021-11-15 | 2021-11-19 | 98 |  |  | 15d | 0d | start no earlier than 2021-11-15 | Trockenbau | 40h |  | Geb.B - 1.OG - Whg |
| 100 | 2.2.1.6 | Estrich | 5d | 2021-11-22 | 2021-11-26 | 99 |  |  | 15d | 0d |  | Estrich | 40h |  | Geb.B - 1.OG - Whg |
| 101 | 2.2.1.7 | Naturstein | 5d | 2021-11-29 | 2021-12-03 | 100 |  |  | 15d | 0d |  | Bodenleger | 40h |  | Geb.B - 1.OG - Whg |
| 102 | 2.2.1.8 | Alutüren | 5d | 2021-12-06 | 2021-12-10 | 101 |  |  | 15d | 0d |  | Türen | 40h |  | Geb.B - 1.OG - Whg |
| 103 | 2.2.1.9 | Maler | 5d | 2021-12-13 | 2021-12-17 | 102 |  |  | 15d | 0d |  | Maler | 40h |  | Geb.B - 1.OG - Whg |
| 104 | 2.2.1.10 | Feininstallation ELT | 5d | 2021-12-20 | 2021-12-24 | 103 |  |  | 15d | 0d |  | Elektro | 40h |  | Geb.B - 1.OG - Whg |
| 105 | 2.2.1.11 | Feininstallation HLS | 5d | 2021-12-20 | 2021-12-24 | 103 |  |  | 25d |  |  | HLS | 40h |  | Geb.B - 1.OG - Whg |
| 106 | 2.2.1.12 | Feinreinigung | 5d | 2021-12-27 | 2021-12-31 | 104 |  |  | 15d | 0d |  | Reinigung | 40h |  | Geb.B - 1.OG - Whg |
| 107 | 2.2.1.13 | Schließzylinder | 5d | 2022-01-03 | 2022-01-07 | 106 |  |  | 15d |  |  | Türen | 40h |  | Geb.B - 1.OG - Whg |
| 108 | 2.3 | **2.OG** | 80d | 2021-09-27 | 2022-01-14 |  |  |  | 10d |  |  |  | 600h |  |  |
| 109 | 2.3.1 | **Wohnung** | 80d | 2021-09-27 | 2022-01-14 |  |  |  | 10d |  |  |  | 600h |  |  |
| 110 | 2.3.1.1 | Unterputz ELT | 5d | 2021-09-27 | 2021-10-01 |  |  |  | 30d | 0d | start no earlier than 2021-09-27 | Elektro | 40h |  | Geb.B - 2.OG - Whg |
| 111 | 2.3.1.2 | Verputzen | 5d | 2021-10-04 | 2021-10-08 | 110 |  |  | 30d | 10d |  | Putz | 40h |  | Geb.B - 2.OG - Whg |
| 112 | 2.3.1.3 | Steigleitung ELT | 10d | 2021-10-25 | 2021-11-05 | 111 |  |  | 60d |  | start no earlier than 2021-10-25 | Elektro | 80h |  | Geb.B - 2.OG - Whg |
| 113 | 2.3.1.4 | Steigleitung HSL | 10d | 2021-10-25 | 2021-11-05 | 111 |  |  | 20d | 10d | start no earlier than 2021-10-25 | HLS | 80h |  | Geb.B - 2.OG - Whg |
| 114 | 2.3.1.5 | TBW | 5d | 2021-11-22 | 2021-11-26 | 113 |  |  | 10d | 0d | start no earlier than 2021-11-22 | Trockenbau | 40h |  | Geb.B - 2.OG - Whg |
| 115 | 2.3.1.6 | Estrich | 5d | 2021-11-29 | 2021-12-03 | 114 |  |  | 10d | 0d |  | Estrich | 40h |  | Geb.B - 2.OG - Whg |
| 116 | 2.3.1.7 | Naturstein | 5d | 2021-12-06 | 2021-12-10 | 115 |  |  | 10d | 0d |  | Bodenleger | 40h |  | Geb.B - 2.OG - Whg |
| 117 | 2.3.1.8 | Alutüren | 5d | 2021-12-13 | 2021-12-17 | 116 |  |  | 10d | 0d |  | Türen | 40h |  | Geb.B - 2.OG - Whg |
| 118 | 2.3.1.9 | Maler | 5d | 2021-12-20 | 2021-12-24 | 117 |  |  | 10d | 0d |  | Maler | 40h |  | Geb.B - 2.OG - Whg |
| 119 | 2.3.1.10 | Feininstallation ELT | 5d | 2021-12-27 | 2021-12-31 | 118 |  |  | 10d | 0d |  | Elektro | 40h |  | Geb.B - 2.OG - Whg |
| 120 | 2.3.1.11 | Feininstallation HLS | 5d | 2021-12-27 | 2021-12-31 | 118 |  |  | 20d |  |  | HLS | 40h |  | Geb.B - 2.OG - Whg |
| 121 | 2.3.1.12 | Feinreinigung | 5d | 2022-01-03 | 2022-01-07 | 119 |  |  | 10d | 0d |  | Reinigung | 40h |  | Geb.B - 2.OG - Whg |
| 122 | 2.3.1.13 | Schließzylinder | 5d | 2022-01-10 | 2022-01-14 | 121 |  |  | 10d |  |  | Türen | 40h |  | Geb.B - 2.OG - Whg |

| ID | WBS | Task | Duration | Start | Finish | Predecessors | Total slack | Free slack | Constraint | Resources | Work | Text22 |
| --- | --- | --- | --- | --- | --- | --- | --- | --- | --- | --- | --- | --- |
| 123 | 2.4 | **3.OG** | 80d | 2021-10-04 | 2022-01-21 |  | 5d |  |  |  | 600h |  |
| 124 | 2.4.1 | **Wohnung** | 80d | 2021-10-04 | 2022-01-21 |  | 5d |  |  |  | 600h |  |
| 125 | 2.4.1.1 | Unterputz ELT | 5d | 2021-10-04 | 2021-10-08 |  | 25d | 0d | start no earlier than 2021-10-04 | Elektro | 40h | Geb.B - 3.OG - Whg |
| 126 | 2.4.1.2 | Verputzen | 5d | 2021-10-11 | 2021-10-15 | 125 | 25d | 15d |  | Putz | 40h | Geb.B - 3.OG - Whg |
| 127 | 2.4.1.3 | Steigleitung ELT | 10d | 2021-11-08 | 2021-11-19 | 126 | 50d |  | start no earlier than 2021-11-08 | Elektro | 80h | Geb.B - 3.OG - Whg |
| 128 | 2.4.1.4 | Steigleitung HSL | 10d | 2021-11-08 | 2021-11-19 | 126 | 10d | 5d | start no earlier than 2021-11-08 | HLS | 80h | Geb.B - 3.OG - Whg |
| 129 | 2.4.1.5 | TBW | 5d | 2021-11-29 | 2021-12-03 | 128 | 5d | 0d | start no earlier than 2021-11-29 | Trockenbau | 40h | Geb.B - 3.OG - Whg |
| 130 | 2.4.1.6 | Estrich | 5d | 2021-12-06 | 2021-12-10 | 129 | 5d | 0d |  | Estrich | 40h | Geb.B - 3.OG - Whg |
| 131 | 2.4.1.7 | Naturstein | 5d | 2021-12-13 | 2021-12-17 | 130 | 5d | 0d |  | Bodenleger | 40h | Geb.B - 3.OG - Whg |
| 132 | 2.4.1.8 | Alutüren | 5d | 2021-12-20 | 2021-12-24 | 131 | 5d | 0d |  | Türen | 40h | Geb.B - 3.OG - Whg |
| 133 | 2.4.1.9 | Maler | 5d | 2021-12-27 | 2021-12-31 | 132 | 5d | 0d |  | Maler | 40h | Geb.B - 3.OG - Whg |
| 134 | 2.4.1.10 | Feininstallation ELT | 5d | 2022-01-03 | 2022-01-07 | 133 | 5d | 0d |  | Elektro | 40h | Geb.B - 3.OG - Whg |
| 135 | 2.4.1.11 | Feininstallation HLS | 5d | 2022-01-03 | 2022-01-07 | 133 | 15d |  |  | HLS | 40h | Geb.B - 3.OG - Whg |
| 136 | 2.4.1.12 | Feinreinigung | 5d | 2022-01-10 | 2022-01-14 | 134 | 5d | 0d |  | Reinigung | 40h | Geb.B - 3.OG - Whg |
| 137 | 2.4.1.13 | Schließzylinder | 5d | 2022-01-17 | 2022-01-21 | 136 | 5d |  |  | Türen | 40h | Geb.B - 3.OG - Whg |
| 138 | 2.5 | **4.OG** | 80d | 2021-10-11 | 2022-01-28 |  | 0d |  |  |  | 600h |  |
| 139 | 2.5.1 | **Wohnung** | 80d | 2021-10-11 | 2022-01-28 |  | 0d |  |  |  | 600h |  |
| 140 | 2.5.1.1 | Unterputz ELT | 5d | 2021-10-11 | 2021-10-15 |  | 20d | 0d | start no earlier than 2021-10-11 | Elektro | 40h | Geb.B - 4.OG - Whg |
| 141 | 2.5.1.2 | Verputzen | 5d | 2021-10-18 | 2021-10-22 | 140 | 20d |  |  | Putz | 40h | Geb.B - 4.OG - Whg |
| 142 | 2.5.1.3 | Steigleitung ELT | 10d | 2021-11-22 | 2021-12-03 | 141 | 40d |  | start no earlier than 2021-11-22 | Elektro | 80h | Geb.B - 4.OG - Whg |
| 143 | 2.5.1.4 | Steigleitung HSL | 10d | 2021-11-22 | 2021-12-03 | 141 | 0d |  | start no earlier than 2021-11-22 | HLS | 80h | Geb.B - 4.OG - Whg |
| 144 | 2.5.1.5 | TBW | 5d | 2021-12-06 | 2021-12-10 | 143 | 0d |  |  | Trockenbau | 40h | Geb.B - 4.OG - Whg |
| 145 | 2.5.1.6 | Estrich | 5d | 2021-12-13 | 2021-12-17 | 144 | 0d |  |  | Estrich | 40h | Geb.B - 4.OG - Whg |
| 146 | 2.5.1.7 | Naturstein | 5d | 2021-12-20 | 2021-12-24 | 145 | 0d |  |  | Bodenleger | 40h | Geb.B - 4.OG - Whg |
| 147 | 2.5.1.8 | Alutüren | 5d | 2021-12-27 | 2021-12-31 | 146 | 0d |  |  | Türen | 40h | Geb.B - 4.OG - Whg |
| 148 | 2.5.1.9 | Maler | 5d | 2022-01-03 | 2022-01-07 | 147 | 0d |  |  | Maler | 40h | Geb.B - 4.OG - Whg |
| 149 | 2.5.1.10 | Feininstallation ELT | 5d | 2022-01-10 | 2022-01-14 | 148 | 0d |  |  | Elektro | 40h | Geb.B - 4.OG - Whg |
| 150 | 2.5.1.11 | Feininstallation HLS | 5d | 2022-01-10 | 2022-01-14 | 148 | 10d |  |  | HLS | 40h | Geb.B - 4.OG - Whg |
| 151 | 2.5.1.12 | Feinreinigung | 5d | 2022-01-17 | 2022-01-21 | 149 | 0d |  |  | Reinigung | 40h | Geb.B - 4.OG - Whg |
| 152 | 2.5.1.13 | Schließzylinder | 5d | 2022-01-24 | 2022-01-28 | 151 | 0d |  |  | Türen | 40h | Geb.B - 4.OG - Whg |
