# Sample Project

Schedule from MS Project, 2021-09-13 to 2022-01-28, A marks actual dates.

## Calendars

- Standard: Mon-Fri 08:00-12:00, 13:00-17:00; Sat-Sun off.

## Resources

| Resource |
| --- |
| Electro |
| Plaster |
| HVS |
| Drywall |
| Screed |
| Floorer |
| Doors |
| Painter |
| Cleaning |

## Schedule

| ID | WBS | Task | Duration | Start | Finish | Predecessors | Complete | Remaining | Total slack | Free slack | Constraint | Resources | Work | Actual work | Text22 |
| --- | --- | --- | --- | --- | --- | --- | --- | --- | --- | --- | --- | --- | --- | --- | --- |
| 1 | 1 | **Project** | 100d | 2021-09-13 A | 2022-01-28 |  | 8% | 91.67d | 0d |  |  |  | 6000h | 500h |  |
| 2 | 1.1 | **Building A** | 100d | 2021-09-13 A | 2022-01-28 |  | 6% | 94d | 0d |  |  |  | 3000h | 180h |  |
| 3 | 1.1.1 | **Groundfloor** | 80d | 2021-09-13 A | 2021-12-31 |  | 23% | 61.33d | 20d |  |  |  | 600h | 140h |  |
| 4 | 1.1.1.1 | **Flat** | 80d | 2021-09-13 A | 2021-12-31 |  | 23% | 61.33d | 20d |  |  |  | 600h | 140h |  |
| 5 | 1.1.1.1.1 | UP Installation Electro | 5d | 2021-09-13 A | 2021-09-17 A |  | 100% |  |  |  | start no earlier than 2021-09-13 | Electro | 40h | 40h | A - 0_GF - Flat |
| 6 | 1.1.1.1.2 | Plastering | 5d | 2021-09-20 A | 2021-09-24 A | 5 | 100% |  |  |  |  | Plaster | 40h | 40h | A - 0_GF - Flat |
| 7 | 1.1.1.1.3 | Ascending strings Electro | 10d | 2021-09-27 A | 2021-10-08 | 6 | 25% | 7.5d | 80d |  |  | Electro | 80h | 20h | A - 0_GF - Flat |
| 8 | 1.1.1.1.4 | Ascending strings HVS | 10d | 2021-09-27 A | 2021-10-08 | 6 | 50% | 5d | 40d | 20d |  | HVS | 80h | 40h | A - 0_GF - Flat |
| 9 | 1.1.1.1.5 | Drywalls | 5d | 2021-11-08 | 2021-11-12 | 8 |  |  | 20d | 0d | start no earlier than 2021-11-08 | Drywall | 40h |  | A - 0_GF - Flat |
| 10 | 1.1.1.1.6 | Screed | 5d | 2021-11-15 | 2021-11-19 | 9 |  |  | 20d | 0d |  | Screed | 40h |  | A - 0_GF - Flat |
| 11 | 1.1.1.1.7 | Natural stone | 5d | 2021-11-22 | 2021-11-26 | 10 |  |  | 20d | 0d |  | Floorer | 40h |  | A - 0_GF - Flat |
| 12 | 1.1.1.1.8 | Aluminum doors | 5d | 2021-11-29 | 2021-12-03 | 11 |  |  | 20d | 0d |  | Doors | 40h |  | A - 0_GF - Flat |
| 13 | 1.1.1.1.9 | Painter | 5d | 2021-12-06 | 2021-12-10 | 12 |  |  | 20d | 0d |  | Painter | 40h |  | A - 0_GF - Flat |
| 14 | 1.1.1.1.10 | Fine Installation Electro | 5d | 2021-12-13 | 2021-12-17 | 13 |  |  | 20d | 0d |  | Electro | 40h |  | A - 0_GF - Flat |
| 15 | 1.1.1.1.11 | Fine Installation HVS | 5d | 2021-12-13 | 2021-12-17 | 13 |  |  | 30d |  |  | HVS | 40h |  | A - 0_GF - Flat |
| 16 | 1.1.1.1.12 | Fine cleaning | 5d | 2021-12-20 | 2021-12-24 | 14 |  |  | 20d | 0d |  | Cleaning | 40h |  | A - 0_GF - Flat |
| 17 | 1.1.1.1.13 | Locking system | 5d | 2021-12-27 | 2021-12-31 | 16 |  |  | 20d |  |  | Doors | 40h |  | A - 0_GF - Flat |
| 18 | 1.1.2 | **1st Floor** | 80d | 2021-09-20 A | 2022-01-07 |  | 7% | 74.67d | 15d |  |  |  | 600h | 40h |  |
| 19 | 1.1.2.1 | **Flat** | 80d | 2021-09-20 A | 2022-01-07 |  | 7% | 74.67d | 15d |  |  |  | 600h | 40h |  |
| 20 | 1.1.2.1.1 | UP Installation Electro | 5d | 2021-09-20 A | 2021-09-24 A |  | 100% |  |  |  | start no earlier than 2021-09-20 | Electro | 40h | 40h | A - 1st Floor - Flat |
| 21 | 1.1.2.1.2 | Plastering | 5d | 2021-09-27 | 2021-10-01 | 20 |  |  | 35d | 5d |  | Plaster | 40h |  | A - 1st Floor - Flat |
| 22 | 1.1.2.1.3 | Ascending strings Electro | 10d | 2021-10-11 | 2021-10-22 | 21 |  |  | 70d |  | start no earlier than 2021-10-11 | Electro | 80h |  | A - 1st Floor - Flat |
| 23 | 1.1.2.1.4 | Ascending strings HVS | 10d | 2021-10-11 | 2021-10-22 | 21 |  |  | 30d | 15d | start no earlier than 2021-10-11 | HVS | 80h |  | A - 1st Floor - Flat |
| 24 | 1.1.2.1.5 | Drywalls | 5d | 2021-11-15 | 2021-11-19 | 23 |  |  | 15d | 0d | start no earlier than 2021-11-15 | Drywall | 40h |  | A - 1st Floor - Flat |
| 25 | 1.1.2.1.6 | Screed | 5d | 2021-11-22 | 2021-11-26 | 24 |  |  | 15d | 0d |  | Screed | 40h |  | A - 1st Floor - Flat |
| 26 | 1.1.2.1.7 | Natural stone | 5d | 2021-11-29 | 2021-12-03 | 25 |  |  | 15d | 0d |  | Floorer | 40h |  | A - 1st Floor - Flat |
| 27 | 1.1.2.1.8 | Aluminum doors | 5d | 2021-12-06 | 2021-12-10 | 26 |  |  | 15d | 0d |  | Doors | 40h |  | A - 1st Floor - Flat |
| 28 | 1.1.2.1.9 | Painter | 5d | 2021-12-13 | 2021-12-17 | 27 |  |  | 15d | 0d |  | Painter | 40h |  | A - 1st Floor - Flat |
| 29 | 1.1.2.1.10 | Fine Installation Electro | 5d | 2021-12-20 | 2021-12-24 | 28 |  |  | 15d | 0d |  | Electro | 40h |  | A - 1st Floor - Flat |
| 30 | 1.1.2.1.11 | Fine Installation HVS | 5d | 2021-12-20 | 2021-12-24 | 28 |  |  | 25d |  |  | HVS | 40h |  | A - 1st Floor - Flat |
| 31 | 1.1.2.1.12 | Fine cleaning | 5d | 2021-12-27 | 2021-12-31 | 29 |  |  | 15d | 0d |  | Cleaning | 40h |  | A - 1st Floor - Flat |
| 32 | 1.1.2.1.13 | Locking system | 5d | 2022-01-03 | 2022-01-07 | 31 |  |  | 15d |  |  | Doors | 40h |  | A - 1st Floor - Flat |

| ID | WBS | Task | Duration | Start | Finish | Predecessors | Total slack | Free slack | Constraint | Resources | Work | Text22 |
| --- | --- | --- | --- | --- | --- | --- | --- | --- | --- | --- | --- | --- |
| 33 | 1.1.3 | **2nd Floor** | 80d | 2021-09-27 | 2022-01-14 |  | 10d |  |  |  | 600h |  |
| 34 | 1.1.3.1 | **Flat** | 80d | 2021-09-27 | 2022-01-14 |  | 10d |  |  |  | 600h |  |
| 35 | 1.1.3.1.1 | UP Installation Electro | 5d | 2021-09-27 | 2021-10-01 |  | 30d | 0d | start no earlier than 2021-09-27 | Electro | 40h | A - 2nd Floor - Flat |
| 36 | 1.1.3.1.2 | Plastering | 5d | 2021-10-04 | 2021-10-08 | 35 | 30d | 10d |  | Plaster | 40h | A - 2nd Floor - Flat |
| 37 | 1.1.3.1.3 | Ascending strings Electro | 10d | 2021-10-25 | 2021-11-05 | 36 | 60d |  | start no earlier than 2021-10-25 | Electro | 80h | A - 2nd Floor - Flat |
| 38 | 1.1.3.1.4 | Ascending strings HVS | 10d | 2021-10-25 | 2021-11-05 | 36 | 20d | 10d | start no earlier than 2021-10-25 | HVS | 80h | A - 2nd Floor - Flat |
| 39 | 1.1.3.1.5 | Drywalls | 5d | 2021-11-22 | 2021-11-26 | 38 | 10d | 0d | start no earlier than 2021-11-22 | Drywall | 40h | A - 2nd Floor - Flat |
| 40 | 1.1.3.1.6 | Screed | 5d | 2021-11-29 | 2021-12-03 | 39 | 10d | 0d |  | Screed | 40h | A - 2nd Floor - Flat |
| 41 | 1.1.3.1.7 | Natural stone | 5d | 2021-12-06 | 2021-12-10 | 40 | 10d | 0d |  | Floorer | 40h | A - 2nd Floor - Flat |
| 42 | 1.1.3.1.8 | Aluminum doors | 5d | 2021-12-13 | 2021-12-17 | 41 | 10d | 0d |  | Doors | 40h | A - 2nd Floor - Flat |
| 43 | 1.1.3.1.9 | Painter | 5d | 2021-12-20 | 2021-12-24 | 42 | 10d | 0d |  | Painter | 40h | A - 2nd Floor - Flat |
| 44 | 1.1.3.1.10 | Fine Installation Electro | 5d | 2021-12-27 | 2021-12-31 | 43 | 10d | 0d |  | Electro | 40h | A - 2nd Floor - Flat |
| 45 | 1.1.3.1.11 | Fine Installation HVS | 5d | 2021-12-27 | 2021-12-31 | 43 | 20d |  |  | HVS | 40h | A - 2nd Floor - Flat |
| 46 | 1.1.3.1.12 | Fine cleaning | 5d | 2022-01-03 | 2022-01-07 | 44 | 10d | 0d |  | Cleaning | 40h | A - 2nd Floor - Flat |
| 47 | 1.1.3.1.13 | Locking system | 5d | 2022-01-10 | 2022-01-14 | 46 | 10d |  |  | Doors | 40h | A - 2nd Floor - Flat |
| 48 | 1.1.4 | **3rd Floor** | 80d | 2021-10-04 | 2022-01-21 |  | 5d |  |  |  | 600h |  |
| 49 | 1.1.4.1 | **Flat** | 80d | 2021-10-04 | 2022-01-21 |  | 5d |  |  |  | 600h |  |
| 50 | 1.1.4.1.1 | UP Installation Electro | 5d | 2021-10-04 | 2021-10-08 |  | 25d | 0d | start no earlier than 2021-10-04 | Electro | 40h | A - 3rd Floor - Flat |
| 51 | 1.1.4.1.2 | Plastering | 5d | 2021-10-11 | 2021-10-15 | 50 | 25d | 15d |  | Plaster | 40h | A - 3rd Floor - Flat |
| 52 | 1.1.4.1.3 | Ascending strings Electro | 10d | 2021-11-08 | 2021-11-19 | 51 | 50d |  | start no earlier than 2021-11-08 | Electro | 80h | A - 3rd Floor - Flat |
| 53 | 1.1.4.1.4 | Ascending strings HVS | 10d | 2021-11-08 | 2021-11-19 | 51 | 10d | 5d | start no earlier than 2021-11-08 | HVS | 80h | A - 3rd Floor - Flat |
| 54 | 1.1.4.1.5 | Drywalls | 5d | 2021-11-29 | 2021-12-03 | 53 | 5d | 0d | start no earlier than 2021-11-29 | Drywall | 40h | A - 3rd Floor - Flat |
| 55 | 1.1.4.1.6 | Screed | 5d | 2021-12-06 | 2021-12-10 | 54 | 5d | 0d |  | Screed | 40h | A - 3rd Floor - Flat |
| 56 | 1.1.4.1.7 | Natural stone | 5d | 2021-12-13 | 2021-12-17 | 55 | 5d | 0d |  | Floorer | 40h | A - 3rd Floor - Flat |
| 57 | 1.1.4.1.8 | Aluminum doors | 5d | 2021-12-20 | 2021-12-24 | 56 | 5d | 0d |  | Doors | 40h | A - 3rd Floor - Flat |
| 58 | 1.1.4.1.9 | Painter | 5d | 2021-12-27 | 2021-12-31 | 57 | 5d | 0d |  | Painter | 40h | A - 3rd Floor - Flat |
| 59 | 1.1.4.1.10 | Fine Installation Electro | 5d | 2022-01-03 | 2022-01-07 | 58 | 5d | 0d |  | Electro | 40h | A - 3rd Floor - Flat |
| 60 | 1.1.4.1.11 | Fine Installation HVS | 5d | 2022-01-03 | 2022-01-07 | 58 | 15d |  |  | HVS | 40h | A - 3rd Floor - Flat |
| 61 | 1.1.4.1.12 | Fine cleaning | 5d | 2022-01-10 | 2022-01-14 | 59 | 5d | 0d |  | Cleaning | 40h | A - 3rd Floor - Flat |
| 62 | 1.1.4.1.13 | Locking system | 5d | 2022-01-17 | 2022-01-21 | 61 | 5d |  |  | Doors | 40h | A - 3rd Floor - Flat |

| ID | WBS | Task | Duration | Start | Finish | Predecessors | Complete | Remaining | Total slack | Free slack | Constraint | Resources | Work | Actual work | Text22 |
| --- | --- | --- | --- | --- | --- | --- | --- | --- | --- | --- | --- | --- | --- | --- | --- |
| 63 | 1.1.5 | **4th Floor** | 80d | 2021-10-11 | 2022-01-28 |  |  |  | 0d |  |  |  | 600h |  |  |
| 64 | 1.1.5.1 | **Flat** | 80d | 2021-10-11 | 2022-01-28 |  |  |  | 0d |  |  |  | 600h |  |  |
| 65 | 1.1.5.1.1 | UP Installation Electro | 5d | 2021-10-11 | 2021-10-15 |  |  |  | 20d | 0d | start no earlier than 2021-10-11 | Electro | 40h |  | A - 4th Floor - Flat |
| 66 | 1.1.5.1.2 | Plastering | 5d | 2021-10-18 | 2021-10-22 | 65 |  |  | 20d |  |  | Plaster | 40h |  | A - 4th Floor - Flat |
| 67 | 1.1.5.1.3 | Ascending strings Electro | 10d | 2021-11-22 | 2021-12-03 | 66 |  |  | 40d |  | start no earlier than 2021-11-22 | Electro | 80h |  | A - 4th Floor - Flat |
| 68 | 1.1.5.1.4 | Ascending strings HVS | 10d | 2021-11-22 | 2021-12-03 | 66 |  |  | 0d |  | start no earlier than 2021-11-22 | HVS | 80h |  | A - 4th Floor - Flat |
| 69 | 1.1.5.1.5 | Drywalls | 5d | 2021-12-06 | 2021-12-10 | 68 |  |  | 0d |  |  | Drywall | 40h |  | A - 4th Floor - Flat |
| 70 | 1.1.5.1.6 | Screed | 5d | 2021-12-13 | 2021-12-17 | 69 |  |  | 0d |  |  | Screed | 40h |  | A - 4th Floor - Flat |
| 71 | 1.1.5.1.7 | Natural stone | 5d | 2021-12-20 | 2021-12-24 | 70 |  |  | 0d |  |  | Floorer | 40h |  | A - 4th Floor - Flat |
| 72 | 1.1.5.1.8 | Aluminum doors | 5d | 2021-12-27 | 2021-12-31 | 71 |  |  | 0d |  |  | Doors | 40h |  | A - 4th Floor - Flat |
| 73 | 1.1.5.1.9 | Painter | 5d | 2022-01-03 | 2022-01-07 | 72 |  |  | 0d |  |  | Painter | 40h |  | A - 4th Floor - Flat |
| 74 | 1.1.5.1.10 | Fine Installation Electro | 5d | 2022-01-10 | 2022-01-14 | 73 |  |  | 0d |  |  | Electro | 40h |  | A - 4th Floor - Flat |
| 75 | 1.1.5.1.11 | Fine Installation HVS | 5d | 2022-01-10 | 2022-01-14 | 73 |  |  | 10d |  |  | HVS | 40h |  | A - 4th Floor - Flat |
| 76 | 1.1.5.1.12 | Fine cleaning | 5d | 2022-01-17 | 2022-01-21 | 74 |  |  | 0d |  |  | Cleaning | 40h |  | A - 4th Floor - Flat |
| 77 | 1.1.5.1.13 | Locking system | 5d | 2022-01-24 | 2022-01-28 | 76 |  |  | 0d |  |  | Doors | 40h |  | A - 4th Floor - Flat |
| 78 | 1.2 | **Building B** | 100d | 2021-09-13 A | 2022-01-28 |  | 11% | 89.33d | 0d |  |  |  | 3000h | 320h |  |
| 79 | 1.2.1 | **Groundfloor** | 80d | 2021-09-13 A | 2021-12-31 |  | 37% | 50.67d | 20d |  |  |  | 600h | 220h |  |
| 80 | 1.2.1.1 | **Flat** | 80d | 2021-09-13 A | 2021-12-31 |  | 37% | 50.67d | 20d |  |  |  | 600h | 220h |  |
| 81 | 1.2.1.1.1 | UP Installation Electro | 5d | 2021-09-13 A | 2021-09-17 A |  | 100% |  |  |  | start no earlier than 2021-09-13 | Electro | 40h | 40h | B - 0_GF - Flat |
| 82 | 1.2.1.1.2 | Plastering | 5d | 2021-09-20 A | 2021-09-24 A | 81 | 100% |  |  |  |  | Plaster | 40h | 40h | B - 0_GF - Flat |
| 83 | 1.2.1.1.3 | Ascending strings Electro | 10d | 2021-09-27 A | 2021-10-08 A | 82 | 100% |  |  |  |  | Electro | 80h | 80h | B - 0_GF - Flat |
| 84 | 1.2.1.1.4 | Ascending strings HVS | 10d | 2021-09-27 A | 2021-10-08 | 82 | 75% | 2.5d | 40d | 20d |  | HVS | 80h | 60h | B - 0_GF - Flat |
| 85 | 1.2.1.1.5 | Drywalls | 5d | 2021-11-08 | 2021-11-12 | 84 |  |  | 20d | 0d | start no earlier than 2021-11-08 | Drywall | 40h |  | B - 0_GF - Flat |
| 86 | 1.2.1.1.6 | Screed | 5d | 2021-11-15 | 2021-11-19 | 85 |  |  | 20d | 0d |  | Screed | 40h |  | B - 0_GF - Flat |
| 87 | 1.2.1.1.7 | Natural stone | 5d | 2021-11-22 | 2021-11-26 | 86 |  |  | 20d | 0d |  | Floorer | 40h |  | B - 0_GF - Flat |
| 88 | 1.2.1.1.8 | Aluminum doors | 5d | 2021-11-29 | 2021-12-03 | 87 |  |  | 20d | 0d |  | Doors | 40h |  | B - 0_GF - Flat |
| 89 | 1.2.1.1.9 | Painter | 5d | 2021-12-06 | 2021-12-10 | 88 |  |  | 20d | 0d |  | Painter | 40h |  | B - 0_GF - Flat |
| 90 | 1.2.1.1.10 | Fine Installation Electro | 5d | 2021-12-13 | 2021-12-17 | 89 |  |  | 20d | 0d |  | Electro | 40h |  | B - 0_GF - Flat |
| 91 | 1.2.1.1.11 | Fine Installation HVS | 5d | 2021-12-13 | 2021-12-17 | 89 |  |  | 30d |  |  | HVS | 40h |  | B - 0_GF - Flat |
| 92 | 1.2.1.1.12 | Fine cleaning | 5d | 2021-12-20 | 2021-12-24 | 90 |  |  | 20d | 0d |  | Cleaning | 40h |  | B - 0_GF - Flat |
| 93 | 1.2.1.1.13 | Locking system | 5d | 2021-12-27 | 2021-12-31 | 92 |  |  | 20d |  |  | Doors | 40h |  | B - 0_GF - Flat |

| ID | WBS | Task | Duration | Start | Finish | Predecessors | Complete | Remaining | Total slack | Free slack | Constraint | Resources | Work | Actual work | Text22 |
| --- | --- | --- | --- | --- | --- | --- | --- | --- | --- | --- | --- | --- | --- | --- | --- |
| 94 | 1.2.2 | **1st Floor** | 80d | 2021-09-20 A | 2022-01-07 |  | 17% | 66.67d | 15d |  |  |  | 600h | 100h |  |
| 95 | 1.2.2.1 | **Flat** | 80d | 2021-09-20 A | 2022-01-07 |  | 17% | 66.67d | 15d |  |  |  | 600h | 100h |  |
| 96 | 1.2.2.1.1 | UP Installation Electro | 5d | 2021-09-20 A | 2021-09-24 A |  | 100% |  |  |  | start no earlier than 2021-09-20 | Electro | 40h | 40h | B - 1st Floor - Flat |
| 97 | 1.2.2.1.2 | Plastering | 5d | 2021-09-27 A | 2021-10-01 A | 96 | 100% |  |  |  |  | Plaster | 40h | 40h | B - 1st Floor - Flat |
| 98 | 1.2.2.1.3 | Ascending strings Electro | 10d | 2021-10-11 A | 2021-10-22 | 97 | 25% | 7.5d | 70d |  | start no earlier than 2021-10-11 | Electro | 80h | 20h | B - 1st Floor - Flat |
| 99 | 1.2.2.1.4 | Ascending strings HVS | 10d | 2021-10-11 | 2021-10-22 | 97 |  |  | 30d | 15d | start no earlier than 2021-10-11 | HVS | 80h |  | B - 1st Floor - Flat |
| 100 | 1.2.2.1.5 | Drywalls | 5d | 2021-11-15 | 2021-11-19 | 99 |  |  | 15d | 0d | start no earlier than 2021-11-15 | Drywall | 40h |  | B - 1st Floor - Flat |
| 101 | 1.2.2.1.6 | Screed | 5d | 2021-11-22 | 2021-11-26 | 100 |  |  | 15d | 0d |  | Screed | 40h |  | B - 1st Floor - Flat |
| 102 | 1.2.2.1.7 | Natural stone | 5d | 2021-11-29 | 2021-12-03 | 101 |  |  | 15d | 0d |  | Floorer | 40h |  | B - 1st Floor - Flat |
| 103 | 1.2.2.1.8 | Aluminum doors | 5d | 2021-12-06 | 2021-12-10 | 102 |  |  | 15d | 0d |  | Doors | 40h |  | B - 1st Floor - Flat |
| 104 | 1.2.2.1.9 | Painter | 5d | 2021-12-13 | 2021-12-17 | 103 |  |  | 15d | 0d |  | Painter | 40h |  | B - 1st Floor - Flat |
| 105 | 1.2.2.1.10 | Fine Installation Electro | 5d | 2021-12-20 | 2021-12-24 | 104 |  |  | 15d | 0d |  | Electro | 40h |  | B - 1st Floor - Flat |
| 106 | 1.2.2.1.11 | Fine Installation HVS | 5d | 2021-12-20 | 2021-12-24 | 104 |  |  | 25d |  |  | HVS | 40h |  | B - 1st Floor - Flat |
| 107 | 1.2.2.1.12 | Fine cleaning | 5d | 2021-12-27 | 2021-12-31 | 105 |  |  | 15d | 0d |  | Cleaning | 40h |  | B - 1st Floor - Flat |
| 108 | 1.2.2.1.13 | Locking system | 5d | 2022-01-03 | 2022-01-07 | 107 |  |  | 15d |  |  | Doors | 40h |  | B - 1st Floor - Flat |
| 109 | 1.2.3 | **2nd Floor** | 80d | 2021-09-27 | 2022-01-14 |  |  |  | 10d |  |  |  | 600h |  |  |
| 110 | 1.2.3.1 | **Flat** | 80d | 2021-09-27 | 2022-01-14 |  |  |  | 10d |  |  |  | 600h |  |  |
| 111 | 1.2.3.1.1 | UP Installation Electro | 5d | 2021-09-27 | 2021-10-01 |  |  |  | 30d | 0d | start no earlier than 2021-09-27 | Electro | 40h |  | B - 2nd Floor - Flat |
| 112 | 1.2.3.1.2 | Plastering | 5d | 2021-10-04 | 2021-10-08 | 111 |  |  | 30d | 10d |  | Plaster | 40h |  | B - 2nd Floor - Flat |
| 113 | 1.2.3.1.3 | Ascending strings Electro | 10d | 2021-10-25 | 2021-11-05 | 112 |  |  | 60d |  | start no earlier than 2021-10-25 | Electro | 80h |  | B - 2nd Floor - Flat |
| 114 | 1.2.3.1.4 | Ascending strings HVS | 10d | 2021-10-25 | 2021-11-05 | 112 |  |  | 20d | 10d | start no earlier than 2021-10-25 | HVS | 80h |  | B - 2nd Floor - Flat |
| 115 | 1.2.3.1.5 | Drywalls | 5d | 2021-11-22 | 2021-11-26 | 114 |  |  | 10d | 0d | start no earlier than 2021-11-22 | Drywall | 40h |  | B - 2nd Floor - Flat |
| 116 | 1.2.3.1.6 | Screed | 5d | 2021-11-29 | 2021-12-03 | 115 |  |  | 10d | 0d |  | Screed | 40h |  | B - 2nd Floor - Flat |
| 117 | 1.2.3.1.7 | Natural stone | 5d | 2021-12-06 | 2021-12-10 | 116 |  |  | 10d | 0d |  | Floorer | 40h |  | B - 2nd Floor - Flat |
| 118 | 1.2.3.1.8 | Aluminum doors | 5d | 2021-12-13 | 2021-12-17 | 117 |  |  | 10d | 0d |  | Doors | 40h |  | B - 2nd Floor - Flat |
| 119 | 1.2.3.1.9 | Painter | 5d | 2021-12-20 | 2021-12-24 | 118 |  |  | 10d | 0d |  | Painter | 40h |  | B - 2nd Floor - Flat |
| 120 | 1.2.3.1.10 | Fine Installation Electro | 5d | 2021-12-27 | 2021-12-31 | 119 |  |  | 10d | 0d |  | Electro | 40h |  | B - 2nd Floor - Flat |
| 121 | 1.2.3.1.11 | Fine Installation HVS | 5d | 2021-12-27 | 2021-12-31 | 119 |  |  | 20d |  |  | HVS | 40h |  | B - 2nd Floor - Flat |
| 122 | 1.2.3.1.12 | Fine cleaning | 5d | 2022-01-03 | 2022-01-07 | 120 |  |  | 10d | 0d |  | Cleaning | 40h |  | B - 2nd Floor - Flat |
| 123 | 1.2.3.1.13 | Locking system | 5d | 2022-01-10 | 2022-01-14 | 122 |  |  | 10d |  |  | Doors | 40h |  | B - 2nd Floor - Flat |

| ID | WBS | Task | Duration | Start | Finish | Predecessors | Total slack | Free slack | Constraint | Resources | Work | Text22 |
| --- | --- | --- | --- | --- | --- | --- | --- | --- | --- | --- | --- | --- |
| 124 | 1.2.4 | **3rd Floor** | 80d | 2021-10-04 | 2022-01-21 |  | 5d |  |  |  | 600h |  |
| 125 | 1.2.4.1 | **Flat** | 80d | 2021-10-04 | 2022-01-21 |  | 5d |  |  |  | 600h |  |
| 126 | 1.2.4.1.1 | UP Installation Electro | 5d | 2021-10-04 | 2021-10-08 |  | 25d | 0d | start no earlier than 2021-10-04 | Electro | 40h | B - 3rd Floor - Flat |
| 127 | 1.2.4.1.2 | Plastering | 5d | 2021-10-11 | 2021-10-15 | 126 | 25d | 15d |  | Plaster | 40h | B - 3rd Floor - Flat |
| 128 | 1.2.4.1.3 | Ascending strings Electro | 10d | 2021-11-08 | 2021-11-19 | 127 | 50d |  | start no earlier than 2021-11-08 | Electro | 80h | B - 3rd Floor - Flat |
| 129 | 1.2.4.1.4 | Ascending strings HVS | 10d | 2021-11-08 | 2021-11-19 | 127 | 10d | 5d | start no earlier than 2021-11-08 | HVS | 80h | B - 3rd Floor - Flat |
| 130 | 1.2.4.1.5 | Drywalls | 5d | 2021-11-29 | 2021-12-03 | 129 | 5d | 0d | start no earlier than 2021-11-29 | Drywall | 40h | B - 3rd Floor - Flat |
| 131 | 1.2.4.1.6 | Screed | 5d | 2021-12-06 | 2021-12-10 | 130 | 5d | 0d |  | Screed | 40h | B - 3rd Floor - Flat |
| 132 | 1.2.4.1.7 | Natural stone | 5d | 2021-12-13 | 2021-12-17 | 131 | 5d | 0d |  | Floorer | 40h | B - 3rd Floor - Flat |
| 133 | 1.2.4.1.8 | Aluminum doors | 5d | 2021-12-20 | 2021-12-24 | 132 | 5d | 0d |  | Doors | 40h | B - 3rd Floor - Flat |
| 134 | 1.2.4.1.9 | Painter | 5d | 2021-12-27 | 2021-12-31 | 133 | 5d | 0d |  | Painter | 40h | B - 3rd Floor - Flat |
| 135 | 1.2.4.1.10 | Fine Installation Electro | 5d | 2022-01-03 | 2022-01-07 | 134 | 5d | 0d |  | Electro | 40h | B - 3rd Floor - Flat |
| 136 | 1.2.4.1.11 | Fine Installation HVS | 5d | 2022-01-03 | 2022-01-07 | 134 | 15d |  |  | HVS | 40h | B - 3rd Floor - Flat |
| 137 | 1.2.4.1.12 | Fine cleaning | 5d | 2022-01-10 | 2022-01-14 | 135 | 5d | 0d |  | Cleaning | 40h | B - 3rd Floor - Flat |
| 138 | 1.2.4.1.13 | Locking system | 5d | 2022-01-17 | 2022-01-21 | 137 | 5d |  |  | Doors | 40h | B - 3rd Floor - Flat |
| 139 | 1.2.5 | **4th Floor** | 80d | 2021-10-11 | 2022-01-28 |  | 0d |  |  |  | 600h |  |
| 140 | 1.2.5.1 | **Flat** | 80d | 2021-10-11 | 2022-01-28 |  | 0d |  |  |  | 600h |  |
| 141 | 1.2.5.1.1 | UP Installation Electro | 5d | 2021-10-11 | 2021-10-15 |  | 20d | 0d | start no earlier than 2021-10-11 | Electro | 40h | B - 4th Floor - Flat |
| 142 | 1.2.5.1.2 | Plastering | 5d | 2021-10-18 | 2021-10-22 | 141 | 20d |  |  | Plaster | 40h | B - 4th Floor - Flat |
| 143 | 1.2.5.1.3 | Ascending strings Electro | 10d | 2021-11-22 | 2021-12-03 | 142 | 40d |  | start no earlier than 2021-11-22 | Electro | 80h | B - 4th Floor - Flat |
| 144 | 1.2.5.1.4 | Ascending strings HVS | 10d | 2021-11-22 | 2021-12-03 | 142 | 0d |  | start no earlier than 2021-11-22 | HVS | 80h | B - 4th Floor - Flat |
| 145 | 1.2.5.1.5 | Drywalls | 5d | 2021-12-06 | 2021-12-10 | 144 | 0d |  |  | Drywall | 40h | B - 4th Floor - Flat |
| 146 | 1.2.5.1.6 | Screed | 5d | 2021-12-13 | 2021-12-17 | 145 | 0d |  |  | Screed | 40h | B - 4th Floor - Flat |
| 147 | 1.2.5.1.7 | Natural stone | 5d | 2021-12-20 | 2021-12-24 | 146 | 0d |  |  | Floorer | 40h | B - 4th Floor - Flat |
| 148 | 1.2.5.1.8 | Aluminum doors | 5d | 2021-12-27 | 2021-12-31 | 147 | 0d |  |  | Doors | 40h | B - 4th Floor - Flat |
| 149 | 1.2.5.1.9 | Painter | 5d | 2022-01-03 | 2022-01-07 | 148 | 0d |  |  | Painter | 40h | B - 4th Floor - Flat |
| 150 | 1.2.5.1.10 | Fine Installation Electro | 5d | 2022-01-10 | 2022-01-14 | 149 | 0d |  |  | Electro | 40h | B - 4th Floor - Flat |
| 151 | 1.2.5.1.11 | Fine Installation HVS | 5d | 2022-01-10 | 2022-01-14 | 149 | 10d |  |  | HVS | 40h | B - 4th Floor - Flat |
| 152 | 1.2.5.1.12 | Fine cleaning | 5d | 2022-01-17 | 2022-01-21 | 150 | 0d |  |  | Cleaning | 40h | B - 4th Floor - Flat |
| 153 | 1.2.5.1.13 | Locking system | 5d | 2022-01-24 | 2022-01-28 | 152 | 0d |  |  | Doors | 40h | B - 4th Floor - Flat |
