# Schulungsprojekt

Schedule from MS Project, 2024-05-13 to 2025-08-22.
LCM Digital

## Calendars

- Standard: Mon-Fri 08:00-12:00, 13:00-17:00; Sat-Sun off.

## Resources

| Resource |
| --- |
| Erdbauer |
| Rohbau |
| Zimmerer |
| Fenster |
| Fassade |
| WDVS |
| Innenputz |
| Trockenbau |
| Sanitär |
| Elektro |
| HLS |
| Türen |
| Maler |
| Boden |
| Reinigung |
| Estrich |
| Systemtrennwände |
| Teppich |
| Meilensteine |
| Außenputz |
| TGA |
| Heizungsbauer |
| Bauherr |
| BH |

## Schedule

| ID | WBS | Task | Type | Duration | Start | Finish | Predecessors | Total slack | Free slack | Resources | Work | Text30 | Text28 | Text29 |
| --- | --- | --- | --- | --- | --- | --- | --- | --- | --- | --- | --- | --- | --- | --- |
| 1 | 1 | **NEW WORK OFFICES** |  | 335d | 2024-05-13 | 2025-08-22 |  | 0d |  |  | 3784h | 1FD76768-7A65-4BC1-9BA7-2DCBA599F6C4 |  |  |
| 2 | 1.1 | **Baugrube** |  | 20d | 2024-05-13 | 2024-06-07 |  | 0d |  |  | 160h |  |  |  |
| 3 | 1.1.1 | Baubeginn | milestone | 0d | 2024-05-13 | 2024-05-13 |  | 335d |  | Meilensteine |  |  |  |  |
| 4 | 1.1.2 | Baugrube |  | 20d | 2024-05-13 | 2024-06-07 |  | 0d |  | Erdbauer | 160h | 76F42543-71BF-49FA-9105-12DFA225BDC2 | 100 | 365 |
| 5 | 1.2 | **Rohbau** |  | 60d | 2024-06-10 | 2024-08-30 |  | 0d |  |  | 480h | 39304D51-1ECD-4585-BFBF-B36A6F4B63C3 |  |  |
| 6 | 1.2.1 | Start Rohbau | milestone | 0d | 2024-06-10 | 2024-06-10 | 7SS | 315d |  | Meilensteine |  |  |  |  |
| 7 | 1.2.2 | Bodenplatte |  | 15d | 2024-06-10 | 2024-06-28 | 4 | 0d |  | Rohbau | 120h | 6C1A954A-0972-43D5-B5C2-5126E6A697A6 | 100,23 | 250 |
| 8 | 1.2.3 | Untergeschoss |  | 10d | 2024-07-01 | 2024-07-12 | 7 | 0d |  | Rohbau | 80h | 38FAD9EE-A47C-471B-80FD-326F232A587B | 100.23 | 500 |
| 9 | 1.2.4 | Erdgeschoss |  | 10d | 2024-07-15 | 2024-07-26 | 8 | 0d |  | Rohbau | 80h | 1F52B91D-2DC6-4A87-8D70-564A12742DD4 | 100 | 500 |
| 10 | 1.2.5 | Obergeschoss |  | 10d | 2024-07-29 | 2024-08-09 | 9 | 0d |  | Rohbau | 80h | 68F43EC3-E554-4A94-8E77-83CF3AE4BE85 | 100 | 400 |
| 11 | 1.2.6 | Dach |  | 15d | 2024-08-12 | 2024-08-30 | 10 | 0d |  | Zimmerer | 120h | ADDF5163-A05D-42C1-A307-DF40EE874424 | 100 | 150 |
| 12 | 1.2.7 | Rohbau fertig | milestone | 0d | 2024-08-30 | 2024-08-30 | 11 | 0d |  | Meilensteine |  |  |  |  |
| 13 | 1.3 | **Fassade** |  | 25d | 2024-09-16 | 2024-10-18 |  | 0d |  |  | 200h |  |  |  |
| 14 | 1.3.1 | Fenster |  | 10d | 2024-09-16 | 2024-09-27 | 12FS+10d | 0d |  | Fenster | 80h |  |  |  |
| 15 | 1.3.2 | Fassade dicht | milestone | 0d | 2024-09-27 | 2024-09-27 | 14 | 220d | 0d | Meilensteine |  |  |  |  |
| 16 | 1.3.3 | WDVS |  | 10d | 2024-09-30 | 2024-10-11 | 15 | 220d | 0d | WDVS | 80h |  |  |  |
| 17 | 1.3.4 | Außenputz |  | 5d | 2024-10-14 | 2024-10-18 | 16 | 220d |  | Außenputz | 40h |  |  |  |
| 18 | 1.4 | **Ausbau** |  | 200d | 2024-10-04 | 2025-07-11 |  | 0d |  |  | 2784h |  |  |  |
| 19 | 1.4.1 | **Büro 1. OG** |  | 100d | 2024-10-04 | 2025-02-21 |  | 0d |  |  | 928h |  |  |  |
| 20 | 1.4.1.1 | Start Ausbau | milestone | 0d | 2024-10-04 | 2024-10-04 | 14FS+5d | 0d |  | Meilensteine |  |  |  |  |
| 21 | 1.4.1.2 | Innenputz |  | 5d | 2024-10-07 | 2024-10-11 | 20 | 0d |  | Innenputz | 40h |  |  |  |
| 22 | 1.4.1.3 | Rohrleitungen HLS |  | 10d | 2024-10-14 | 2024-10-25 | 21 | 30d | 0d | HLS | 80h |  |  |  |
| 23 | 1.4.1.4 | Leitungen Boden |  | 5d | 2024-10-21 | 2024-10-25 | 22SS+5d | 30d | 0d | Elektro | 40h |  |  |  |
| 24 | 1.4.1.5 | Hohlboden |  | 5d | 2024-10-28 | 2024-11-01 | 22, 23 | 30d | 0d | Boden | 40h |  |  |  |
| 25 | 1.4.1.6 | Estrich |  | 2d | 2024-11-04 | 2024-11-05 | 24 | 30d | 0d | Estrich | 16h |  |  |  |
| 26 | 1.4.1.7 | Estrich Trocknung |  | 8d | 2024-11-06 | 2024-11-15 | 25 | 30d | 0d | Estrich | 64h |  |  |  |
| 27 | 1.4.1.8 | Eckwand + 1. Seite |  | 5d | 2024-11-18 | 2024-11-22 | 26 | 30d | 0d | Trockenbau | 40h |  |  |  |
| 28 | 1.4.1.9 | Leitung Wand |  | 5d | 2024-11-25 | 2024-11-29 | 27 | 30d | 0d | Elektro | 40h |  |  |  |
| 29 | 1.4.1.10 | 2. Seite + Q3 |  | 5d | 2024-12-02 | 2024-12-06 | 28 | 30d | 0d | Trockenbau | 40h |  |  |  |
| 30 | 1.4.1.11 | 1. Anstrich |  | 5d | 2024-12-09 | 2024-12-13 | 29 | 30d | 0d | Maler | 40h |  |  |  |
| 31 | 1.4.1.12 | Systemtrennwände |  | 10d | 2024-12-16 | 2024-12-27 | 30 | 30d | 0d | Systemtrennwände | 80h |  |  |  |
| 32 | 1.4.1.13 | Bodenbelag |  | 5d | 2024-12-30 | 2025-01-03 | 31 | 30d | 0d | Teppich | 40h |  |  |  |
| 33 | 1.4.1.14 | Bodentanks |  | 5d | 2025-01-06 | 2025-01-10 | 32 | 30d | 0d | Teppich | 40h |  |  |  |
| 34 | 1.4.1.15 | Türen |  | 5d | 2025-01-06 | 2025-01-10 | 33SS | 30d | 0d | Türen | 40h |  |  |  |
| 35 | 1.4.1.16 | Heizkörper |  | 5d | 2025-01-13 | 2025-01-17 | 34, 33 | 30d | 0d | Heizungsbauer | 40h |  |  |  |
| 36 | 1.4.1.17 | Feininstallation HLS |  | 10d | 2025-01-13 | 2025-01-24 | 35SS | 30d | 0d | HLS | 80h |  |  |  |
| 37 | 1.4.1.18 | Schließzylinder |  | 1d | 2025-01-27 | 2025-01-27 | 36 | 30d | 0d | Bauherr | 8h |  |  |  |
| 38 | 1.4.1.19 | Schalter + Lampen |  | 5d | 2025-01-27 | 2025-01-31 | 37SS | 30d | 0d | Elektro | 40h |  |  |  |
| 39 | 1.4.1.20 | 2. Anstrich |  | 5d | 2025-02-03 | 2025-02-07 | 38 | 30d | 0d | Maler | 40h |  |  |  |
| 40 | 1.4.1.21 | WC-Gegenstände |  | 5d | 2025-02-10 | 2025-02-14 | 39, 37 | 30d | 0d | Sanitär | 40h |  |  |  |
| 41 | 1.4.1.22 | Endreinigung |  | 5d | 2025-02-17 | 2025-02-21 | 40 | 30d |  | Reinigung | 40h |  |  |  |

| ID | WBS | Task | Type | Duration | Start | Finish | Predecessors | Total slack | Free slack | Resources | Work |
| --- | --- | --- | --- | --- | --- | --- | --- | --- | --- | --- | --- |
| 42 | 1.4.2 | **Büro 2. OG** |  | 105d | 2024-10-21 | 2025-03-14 |  | 0d |  |  | 928h |
| 43 | 1.4.2.1 | Innenputz |  | 5d | 2024-10-21 | 2024-10-25 | 21FS+5d | 0d |  | Innenputz | 40h |
| 44 | 1.4.2.2 | Rohrleitungen HLS |  | 10d | 2024-10-28 | 2024-11-08 | 43 | 15d | 0d | HLS | 80h |
| 45 | 1.4.2.3 | Leitungen Boden |  | 5d | 2024-11-04 | 2024-11-08 | 44SS+5d | 15d | 0d | Elektro | 40h |
| 46 | 1.4.2.4 | Hohlboden |  | 5d | 2024-11-11 | 2024-11-15 | 44, 45 | 15d | 0d | Boden | 40h |
| 47 | 1.4.2.5 | Estrich |  | 2d | 2024-11-18 | 2024-11-19 | 46 | 15d | 0d | Estrich | 16h |
| 48 | 1.4.2.6 | Estrich Trocknung |  | 8d | 2024-11-20 | 2024-11-29 | 47 | 15d | 0d | Estrich | 64h |
| 49 | 1.4.2.7 | Eckwand + 1. Seite |  | 5d | 2024-12-09 | 2024-12-13 | 48FS+5d | 15d | 0d | Trockenbau | 40h |
| 50 | 1.4.2.8 | Leitung Wand |  | 5d | 2024-12-16 | 2024-12-20 | 49 | 15d | 0d | Elektro | 40h |
| 51 | 1.4.2.9 | 2. Seite + Q3 |  | 5d | 2024-12-23 | 2024-12-27 | 50 | 15d | 0d | Trockenbau | 40h |
| 52 | 1.4.2.10 | 1. Anstrich |  | 5d | 2024-12-30 | 2025-01-03 | 51 | 15d | 0d | Maler | 40h |
| 53 | 1.4.2.11 | Systemtrennwände |  | 10d | 2025-01-06 | 2025-01-17 | 52 | 15d | 0d | Systemtrennwände | 80h |
| 54 | 1.4.2.12 | Bodenbelag |  | 5d | 2025-01-20 | 2025-01-24 | 53 | 15d | 0d | Teppich | 40h |
| 55 | 1.4.2.13 | Bodentanks |  | 5d | 2025-01-27 | 2025-01-31 | 54 | 15d | 0d | Teppich | 40h |
| 56 | 1.4.2.14 | Türen |  | 5d | 2025-01-27 | 2025-01-31 | 55SS | 15d | 0d | Türen | 40h |
| 57 | 1.4.2.15 | Heizkörper |  | 5d | 2025-02-03 | 2025-02-07 | 56, 55 | 15d | 0d | Heizungsbauer | 40h |
| 58 | 1.4.2.16 | Feininstallation HLS |  | 10d | 2025-02-03 | 2025-02-14 | 57SS | 15d | 0d | HLS | 80h |
| 59 | 1.4.2.17 | Schließzylinder |  | 1d | 2025-02-17 | 2025-02-17 | 58 | 15d | 0d | Bauherr | 8h |
| 60 | 1.4.2.18 | Schalter + Lampen |  | 5d | 2025-02-17 | 2025-02-21 | 59SS | 15d | 0d | Elektro | 40h |
| 61 | 1.4.2.19 | 2. Anstrich |  | 5d | 2025-02-24 | 2025-02-28 | 60 | 15d | 0d | Maler | 40h |
| 62 | 1.4.2.20 | WC-Gegenstände |  | 5d | 2025-03-03 | 2025-03-07 | 61, 59 | 15d | 0d | Sanitär | 40h |
| 63 | 1.4.2.21 | Endreinigung |  | 5d | 2025-03-10 | 2025-03-14 | 62 | 15d |  | Reinigung | 40h |
| 64 | 1.4.3 | **Büro 3. OG** |  | 110d | 2024-11-04 | 2025-04-04 |  | 0d |  |  | 928h |
| 65 | 1.4.3.1 | Innenputz |  | 5d | 2024-11-04 | 2024-11-08 | 43FS+5d | 0d |  | Innenputz | 40h |
| 66 | 1.4.3.2 | Rohrleitungen HLS |  | 10d | 2024-11-11 | 2024-11-22 | 65 | 0d |  | HLS | 80h |
| 67 | 1.4.3.3 | Leitungen Boden |  | 5d | 2024-11-18 | 2024-11-22 | 66SS+5d | 0d |  | Elektro | 40h |
| 68 | 1.4.3.4 | Hohlboden |  | 5d | 2024-11-25 | 2024-11-29 | 66, 67 | 0d |  | Boden | 40h |
| 69 | 1.4.3.5 | Estrich |  | 2d | 2024-12-02 | 2024-12-03 | 68 | 0d |  | Estrich | 16h |
| 70 | 1.4.3.6 | Estrich Trocknung |  | 8d | 2024-12-04 | 2024-12-13 | 69 | 0d |  | Estrich | 64h |
| 71 | 1.4.3.7 | Eckwand + 1. Seite |  | 5d | 2024-12-30 | 2025-01-03 | 70FS+10d | 0d |  | Trockenbau | 40h |
| 72 | 1.4.3.8 | Leitung Wand |  | 5d | 2025-01-06 | 2025-01-10 | 71 | 0d |  | Elektro | 40h |
| 73 | 1.4.3.9 | 2. Seite + Q3 |  | 5d | 2025-01-13 | 2025-01-17 | 72 | 0d |  | Trockenbau | 40h |
| 74 | 1.4.3.10 | 1. Anstrich |  | 5d | 2025-01-20 | 2025-01-24 | 73 | 0d |  | Maler | 40h |
| 75 | 1.4.3.11 | Systemtrennwände |  | 10d | 2025-01-27 | 2025-02-07 | 74 | 0d |  | Systemtrennwände | 80h |
| 76 | 1.4.3.12 | Bodenbelag |  | 5d | 2025-02-10 | 2025-02-14 | 75 | 0d |  | Teppich | 40h |
| 77 | 1.4.3.13 | Bodentanks |  | 5d | 2025-02-17 | 2025-02-21 | 76 | 0d |  | Teppich | 40h |
| 78 | 1.4.3.14 | Türen |  | 5d | 2025-02-17 | 2025-02-21 | 77SS | 0d |  | Türen | 40h |
| 79 | 1.4.3.15 | Heizkörper |  | 5d | 2025-02-24 | 2025-02-28 | 78, 77 | 0d |  | Heizungsbauer | 40h |
| 80 | 1.4.3.16 | Feininstallation HLS |  | 10d | 2025-02-24 | 2025-03-07 | 79SS | 0d |  | HLS | 80h |
| 81 | 1.4.3.17 | Schließzylinder |  | 1d | 2025-03-10 | 2025-03-10 | 80 | 0d |  | Bauherr | 8h |
| 82 | 1.4.3.18 | Schalter + Lampen |  | 5d | 2025-03-10 | 2025-03-14 | 81SS | 0d |  | Elektro | 40h |
| 83 | 1.4.3.19 | 2. Anstrich |  | 5d | 2025-03-17 | 2025-03-21 | 82 | 0d |  | Maler | 40h |
| 84 | 1.4.3.20 | WC-Gegenstände |  | 5d | 2025-03-24 | 2025-03-28 | 83, 81 | 0d |  | Sanitär | 40h |
| 85 | 1.4.3.21 | Endreinigung |  | 5d | 2025-03-31 | 2025-04-04 | 84 | 0d |  | Reinigung | 40h |
| 86 | 1.4.3.22 | Ausbau fertig | milestone | 0d | 2025-04-04 | 2025-04-04 | 85, 41, 63 | 0d |  | Meilensteine |  |

| ID | WBS | Task | Type | Duration | Start | Finish | Predecessors | Total slack | Resources | Work |
| --- | --- | --- | --- | --- | --- | --- | --- | --- | --- | --- |
| 87 | 1.4.4 | **Mängelbeseitigung** |  | 35d | 2025-05-26 | 2025-07-11 |  | 0d |  |  |
| 88 | 1.4.4.1 | Mängelaufnahme |  | 5d | 2025-05-26 | 2025-05-30 | 94FS+5d | 0d |  |  |
| 89 | 1.4.4.2 | Dokumentation |  | 5d | 2025-06-02 | 2025-06-06 | 88 | 0d |  |  |
| 90 | 1.4.4.3 | Mängelabarbeitung |  | 20d | 2025-06-09 | 2025-07-04 | 89 | 0d |  |  |
| 91 | 1.4.4.4 | Nachkontrolle |  | 5d | 2025-07-07 | 2025-07-11 | 90 | 0d |  |  |
| 92 | 1.4.4.5 | Mängelfrei | milestone | 0d | 2025-07-11 | 2025-07-11 | 91 | 0d | Meilensteine |  |
| 93 | 1.5 | **Inbetriebnahme** |  | 90d | 2025-04-21 | 2025-08-22 |  | 0d |  | 160h |
| 94 | 1.5.1 | Inbetriebnahme TGA |  | 20d | 2025-04-21 | 2025-05-16 | 86FS+10d, 85 | 0d | TGA | 160h |
| 95 | 1.5.2 | Übergabe an Bauherr | milestone | 0d | 2025-07-18 | 2025-07-18 | 92FS+5d | 0d | Meilensteine |  |
| 96 | 1.5.3 | Einzug Kunde |  | 10d | 2025-08-11 | 2025-08-22 | 95FS+15d | 0d |  |  |
