# 260116-Beispielprojekt

Schedule from MS Project, 2025-04-28 to 2026-07-20, A marks actual dates.

## Calendars

- Standard: Mon-Fri 08:00-12:00, 13:00-17:00; Sat-Sun off.

## Resources

| Resource |
| --- |
| Erdbauer |
| Rohbau |
| Zimmerer |
| Fenster |
| WDVS |
| Innenputz |
| Trockenbau |
| Sanitär - Fa. Rohr Frei |
| Elektro - Fa. Elektro Blitz |
| HLS |
| Türen |
| Maler |
| Boden |
| Reinigung - Fa. Gebäudereinigung Blitzblank |
| Estrich |
| Systemtrennwände |
| Teppich |
| Meilensteine |
| Außenputz |
| TGA |
| Heizungsbauer |
| Bauherr |
| Küchenbauer |
| Außenanlagen - Fa. Meier |
| Mängelmanagement |
| Außenputz |
| Fenster |
| Estrich |
| Erdbauer |
| Boden |
| Außenanlagen |
| Meilenstein |

## Schedule

| ID | WBS | Task | Type | Duration | Start | Finish | Predecessors | Complete | Remaining | Actual finish | Baseline start | Baseline finish | Baseline duration | Resources | Work | Actual work |
| --- | --- | --- | --- | --- | --- | --- | --- | --- | --- | --- | --- | --- | --- | --- | --- | --- |
| 1 | 1 | **Gebäude 1** |  | 1d | 2025-04-28 A | 2025-04-28 |  | 57% | 0.43d |  | 2024-05-20 | 2025-07-28 | 0d |  | 4872h | 2784h |
| 2 | 1.1 | **Baugrube** |  | 1d | 2025-04-28 A | 2025-04-28 |  | 100% |  | 2025-06-06 | 2024-05-20 | 2024-06-14 | 0d |  | 160h | 160h |
| 3 | 1.1.1 | Baugrube | manual | 20d | 2025-05-12 A | 2025-06-06 A |  | 100% |  |  | 2024-05-20 | 2024-06-14 | 20d | Erdbauer | 160h | 160h |
| 4 | 1.1.2 | Baubeginn | milestone, manual | 0d | 2025-04-28 A | 2025-04-28 A |  | 100% |  |  | 2024-05-20 | 2024-05-20 | 0d | Meilensteine |  |  |
| 5 | 1.2 | **Rohbau** |  | 1d | 2025-06-09 A | 2025-06-09 |  | 100% |  | 2025-09-01 | 2024-06-17 | 2024-09-09 | 0d |  | 480h | 480h |
| 6 | 1.2.1 | Bodenplatte | manual | 15d | 2025-06-09 A | 2025-06-27 A | 3 | 100% |  |  | 2024-06-17 | 2024-07-05 | 15d | Rohbau | 120h | 120h |
| 7 | 1.2.2 | Untergeschoss | manual | 10d | 2025-06-30 A | 2025-07-11 A | 6 | 100% |  |  | 2024-07-08 | 2024-07-19 | 10d | Rohbau | 80h | 80h |
| 8 | 1.2.3 | Erdgeschoss | manual | 10d | 2025-07-14 A | 2025-07-25 A | 7 | 100% |  |  | 2024-07-22 | 2024-08-02 | 10d | Rohbau | 80h | 80h |
| 9 | 1.2.4 | Obergeschoss | manual | 10d | 2025-07-28 A | 2025-08-08 A | 8 | 100% |  |  | 2024-08-05 | 2024-08-16 | 10d | Rohbau | 80h | 80h |
| 10 | 1.2.5 | Dach | manual | 15d | 2025-08-11 A | 2025-08-29 A | 9 | 100% |  |  | 2024-08-19 | 2024-09-06 | 15d |  | 120h | 120h |
| 11 | 1.2.6 | Rohbau fertig | milestone, manual | 0d | 2025-09-01 A | 2025-09-01 A | 10 | 100% |  |  | 2024-09-09 | 2024-09-09 | 0d | Meilensteine |  |  |
| 12 | 1.2.7 | Start Rohbau | milestone, manual | 0d | 2025-06-09 A | 2025-06-09 A | 6SS | 100% |  |  | 2024-06-17 | 2024-06-17 | 0d | Meilensteine |  |  |
| 13 | 1.3 | **Fassade** |  | 1d | 2025-09-15 A | 2025-09-15 |  | 100% |  | 2025-10-17 | 2024-09-23 | 2024-10-25 | 0d |  | 200h | 200h |
| 14 | 1.3.1 | Fenster | manual | 10d | 2025-09-15 A | 2025-09-26 A | 11FS+10d | 100% |  |  | 2024-09-23 | 2024-10-04 | 10d | Fenster | 80h | 80h |
| 15 | 1.3.2 | Fassade dicht | milestone, manual | 0d | 2025-09-29 A | 2025-09-29 A | 14 | 100% |  |  | 2024-10-07 | 2024-10-07 | 0d | Meilensteine |  |  |
| 16 | 1.3.3 | WDVS | manual | 10d | 2025-09-29 A | 2025-10-10 A | 15 | 100% |  |  | 2024-10-07 | 2024-10-18 | 10d | WDVS | 80h | 80h |
| 17 | 1.3.4 | Außenputz | manual | 5d | 2025-10-13 A | 2025-10-17 A | 16 | 100% |  |  | 2024-10-21 | 2024-10-25 | 5d | Außenputz | 40h | 40h |
| 18 | 1.4 | **Ausbau** |  | 1d | 2025-10-06 A | 2025-10-06 |  | 50% | 0.5d |  | 2024-10-14 | 2025-07-21 | 0d |  | 3872h | 1944h |
| 19 | 1.4.1 | **Büro 1. OG** |  | 1d | 2025-10-06 A | 2025-10-06 |  | 76% | 0.24d |  | 2024-10-14 | 2025-02-28 | 0d |  | 928h | 704h |
| 20 | 1.4.1.1 | Start Ausbau | milestone, manual | 0d | 2025-10-06 A | 2025-10-06 A | 14FS+5d | 100% |  |  | 2024-10-14 | 2024-10-14 | 0d | Meilensteine |  |  |
| 21 | 1.4.1.2 | Innenputz | manual | 5d | 2025-10-06 A | 2025-10-10 A | 20 | 100% |  |  | 2024-10-14 | 2024-10-18 | 5d | Innenputz | 40h | 40h |
| 22 | 1.4.1.3 | Rohrleitungen HLS | manual | 10d | 2025-10-13 A | 2025-10-24 A | 21 | 100% |  |  | 2024-10-21 | 2024-11-01 | 10d | HLS | 80h | 80h |
| 23 | 1.4.1.4 | Leitungen Boden | manual | 5d | 2025-10-20 A | 2025-10-24 A | 22SS+5d | 100% |  |  | 2024-10-28 | 2024-11-01 | 5d | Elektro - Fa. Elektro Blitz | 40h | 40h |
| 24 | 1.4.1.5 | Hohlboden | manual | 5d | 2025-10-27 A | 2025-10-31 A | 23, 22 | 100% |  |  | 2024-11-04 | 2024-11-08 | 5d | Boden | 40h | 40h |
| 25 | 1.4.1.6 | Estrich | manual | 2d | 2025-11-03 A | 2025-11-04 A | 24 | 100% |  |  | 2024-11-11 | 2024-11-12 | 2d | Estrich | 16h | 16h |
| 26 | 1.4.1.7 | Estrich Trocknung | manual | 8d | 2025-11-05 A | 2025-11-14 A | 25 | 100% |  |  | 2024-11-13 | 2024-11-22 | 8d | Estrich | 64h | 64h |
| 27 | 1.4.1.8 | Eckwand + 1. Seite | manual | 5d | 2025-11-17 A | 2025-11-21 A | 26 | 100% |  |  | 2024-11-25 | 2024-11-29 | 5d | Trockenbau | 40h | 40h |
| 28 | 1.4.1.9 | Leitung Wand | manual | 5d | 2025-11-24 A | 2025-11-28 A | 27 | 100% |  |  | 2024-12-02 | 2024-12-06 | 5d | Elektro - Fa. Elektro Blitz | 40h | 40h |
| 29 | 1.4.1.10 | 2. Seite + Q3 | manual | 5d | 2025-12-01 A | 2025-12-05 A | 28 | 100% |  |  | 2024-12-09 | 2024-12-13 | 5d | Trockenbau | 40h | 40h |
| 30 | 1.4.1.11 | 1. Anstrich | manual | 5d | 2025-12-08 A | 2025-12-12 A | 29 | 100% |  |  | 2024-12-16 | 2024-12-20 | 5d | Maler | 40h | 40h |
| 31 | 1.4.1.12 | Systemtrennwände | manual | 10d | 2025-12-15 A | 2025-12-26 A | 30 | 100% |  |  | 2024-12-23 | 2025-01-03 | 10d | Systemtrennwände | 80h | 80h |
| 32 | 1.4.1.13 | Bodenbelag | manual | 5d | 2025-12-29 A | 2026-01-02 A | 31 | 100% |  |  | 2025-01-06 | 2025-01-10 | 5d | Teppich | 40h | 40h |
| 33 | 1.4.1.14 | Bodentanks | manual | 5d | 2026-01-05 A | 2026-01-09 A | 32 | 100% |  |  | 2025-01-13 | 2025-01-17 | 5d | Teppich | 40h | 40h |
| 34 | 1.4.1.15 | Türen | manual | 5d | 2026-01-05 A | 2026-01-09 A | 33SS | 100% |  |  | 2025-01-13 | 2025-01-17 | 5d | Türen | 40h | 40h |
| 35 | 1.4.1.16 | Heizkörper | manual | 5d | 2026-01-12 A | 2026-01-16 | 33, 34 | 80% | 1d |  | 2025-01-20 | 2025-01-24 | 5d | Heizungsbauer | 40h | 32h |
| 36 | 1.4.1.17 | Feininstallation HLS | manual | 10d | 2026-01-12 A | 2026-01-23 | 35SS | 40% | 6d |  | 2025-01-20 | 2025-01-31 | 10d | HLS | 80h | 32h |
| 37 | 1.4.1.18 | Schließzylinder | manual | 1d | 2026-01-26 | 2026-01-26 | 36 |  |  |  | 2025-02-03 | 2025-02-03 | 1d | Bauherr | 8h |  |
| 38 | 1.4.1.19 | Schalter + Lampen | manual | 5d | 2026-01-26 | 2026-01-30 | 37SS |  |  |  | 2025-02-03 | 2025-02-07 | 5d | Elektro - Fa. Elektro Blitz | 40h |  |
| 39 | 1.4.1.20 | 2. Anstrich | manual | 5d | 2026-02-02 | 2026-02-06 | 38 |  |  |  | 2025-02-10 | 2025-02-14 | 5d | Maler | 40h |  |
| 40 | 1.4.1.21 | WC-Gegenstände | manual | 5d | 2026-02-09 | 2026-02-13 | 37, 39 |  |  |  | 2025-02-17 | 2025-02-21 | 5d | Sanitär - Fa. Rohr Frei | 40h |  |
| 41 | 1.4.1.22 | Endreinigung | manual | 5d | 2026-02-16 | 2026-02-20 | 40 |  |  |  | 2025-02-24 | 2025-02-28 | 5d | Reinigung - Fa. Gebäudereinigung Blitzblank | 40h |  |
| 42 | 1.4.1.23 | Außenanlagen VP2 | milestone, manual | 0d | 2025-12-08 A | 2025-12-08 A |  | 100% |  |  |  |  |  | Außenanlagen |  |  |

| ID | WBS | Task | Type | Duration | Start | Finish | Predecessors | Complete | Remaining | Baseline start | Baseline finish | Baseline duration | Resources | Work | Actual work |
| --- | --- | --- | --- | --- | --- | --- | --- | --- | --- | --- | --- | --- | --- | --- | --- |
| 43 | 1.4.2 | **Büro 2. OG** |  | 1d | 2025-10-20 A | 2025-10-20 |  | 55% | 0.45d | 2024-10-28 | 2025-03-21 | 0d |  | 928h | 512h |
| 44 | 1.4.2.1 | Innenputz | manual | 5d | 2025-10-20 A | 2025-10-24 A | 21FS+5d | 100% |  | 2024-10-28 | 2024-11-01 | 5d | Innenputz | 40h | 40h |
| 45 | 1.4.2.2 | Rohrleitungen HLS | manual | 10d | 2025-10-27 A | 2025-11-07 A | 44 | 100% |  | 2024-11-04 | 2024-11-15 | 10d | HLS | 80h | 80h |
| 46 | 1.4.2.3 | Leitungen Boden | manual | 5d | 2025-11-03 A | 2025-11-07 A | 45SS+5d | 100% |  | 2024-11-11 | 2024-11-15 | 5d | Elektro - Fa. Elektro Blitz | 40h | 40h |
| 47 | 1.4.2.4 | Hohlboden | manual | 5d | 2025-11-10 A | 2025-11-14 A | 46, 45 | 100% |  | 2024-11-18 | 2024-11-22 | 5d | Boden | 40h | 40h |
| 48 | 1.4.2.5 | Estrich | manual | 2d | 2025-11-17 A | 2025-11-18 A | 47 | 100% |  | 2024-11-25 | 2024-11-26 | 2d | Estrich | 16h | 16h |
| 49 | 1.4.2.6 | Estrich Trocknung | manual | 8d | 2025-11-19 A | 2025-11-28 A | 48 | 100% |  | 2024-11-27 | 2024-12-06 | 8d | Estrich | 64h | 64h |
| 50 | 1.4.2.7 | Eckwand + 1. Seite | manual | 5d | 2025-12-08 A | 2025-12-12 A | 49FS+5d | 100% |  | 2024-12-16 | 2024-12-20 | 5d | Trockenbau | 40h | 40h |
| 51 | 1.4.2.8 | Leitung Wand | manual | 5d | 2025-12-15 A | 2025-12-19 A | 50 | 100% |  | 2024-12-23 | 2024-12-27 | 5d | Elektro - Fa. Elektro Blitz | 40h | 40h |
| 52 | 1.4.2.9 | 2. Seite + Q3 | manual | 5d | 2025-12-22 A | 2025-12-26 A | 51 | 100% |  | 2024-12-30 | 2025-01-03 | 5d | Trockenbau | 40h | 40h |
| 53 | 1.4.2.10 | 1. Anstrich | manual | 5d | 2025-12-29 A | 2026-01-02 A | 52 | 100% |  | 2025-01-06 | 2025-01-10 | 5d | Maler | 40h | 40h |
| 54 | 1.4.2.11 | Systemtrennwände | manual | 10d | 2026-01-05 A | 2026-01-16 | 53 | 90% | 1d | 2025-01-13 | 2025-01-24 | 10d | Systemtrennwände | 80h | 72h |
| 55 | 1.4.2.12 | Bodenbelag | manual | 5d | 2026-01-19 | 2026-01-23 | 54 |  |  | 2025-01-27 | 2025-01-31 | 5d | Teppich | 40h |  |
| 56 | 1.4.2.13 | Bodentanks | manual | 5d | 2026-01-26 | 2026-01-30 | 55 |  |  | 2025-02-03 | 2025-02-07 | 5d | Teppich | 40h |  |
| 57 | 1.4.2.14 | Türen | manual | 5d | 2026-01-26 | 2026-01-30 | 56SS |  |  | 2025-02-03 | 2025-02-07 | 5d | Türen | 40h |  |
| 58 | 1.4.2.15 | Heizkörper | manual | 5d | 2026-02-02 | 2026-02-06 | 56, 57 |  |  | 2025-02-10 | 2025-02-14 | 5d | Heizungsbauer | 40h |  |
| 59 | 1.4.2.16 | Feininstallation HLS | manual | 10d | 2026-02-02 | 2026-02-13 | 58SS |  |  | 2025-02-10 | 2025-02-21 | 10d | HLS | 80h |  |
| 60 | 1.4.2.17 | Schließzylinder | manual | 1d | 2026-02-16 | 2026-02-16 | 59 |  |  | 2025-02-24 | 2025-02-24 | 1d | Bauherr | 8h |  |
| 61 | 1.4.2.18 | Schalter + Lampen | manual | 5d | 2026-02-16 | 2026-02-20 | 60SS |  |  | 2025-02-24 | 2025-02-28 | 5d | Elektro - Fa. Elektro Blitz | 40h |  |
| 62 | 1.4.2.19 | 2. Anstrich | manual | 5d | 2026-02-23 | 2026-02-27 | 61 |  |  | 2025-03-03 | 2025-03-07 | 5d | Maler | 40h |  |
| 63 | 1.4.2.20 | WC-Gegenstände | manual | 5d | 2026-03-02 | 2026-03-06 | 60, 62 |  |  | 2025-03-10 | 2025-03-14 | 5d | Sanitär - Fa. Rohr Frei | 40h |  |
| 64 | 1.4.2.21 | Endreinigung | manual | 5d | 2026-03-09 | 2026-03-13 | 63 |  |  | 2025-03-17 | 2025-03-21 | 5d | Reinigung - Fa. Gebäudereinigung Blitzblank | 40h |  |
| 65 | 1.4.3 | **Büro 3. OG** |  | 1d | 2025-10-27 A | 2025-10-27 |  | 42% | 0.58d | 2024-11-11 | 2025-04-14 | 0d |  | 928h | 392h |
| 66 | 1.4.3.1 | Innenputz | manual | 5d | 2025-10-27 A | 2025-10-31 A | 44 | 100% |  | 2024-11-11 | 2024-11-15 | 5d | Innenputz | 40h | 40h |
| 67 | 1.4.3.2 | Rohrleitungen HLS | manual | 10d | 2025-11-10 A | 2025-11-21 A | 66, 45 | 100% |  | 2024-11-18 | 2024-11-29 | 10d | HLS | 80h | 80h |
| 68 | 1.4.3.3 | Leitungen Boden | manual | 5d | 2025-11-17 A | 2025-11-21 A | 67SS+5d | 100% |  | 2024-11-25 | 2024-11-29 | 5d | Elektro - Fa. Elektro Blitz | 40h | 40h |
| 69 | 1.4.3.4 | Hohlboden | manual | 5d | 2025-11-24 A | 2025-11-28 A | 68, 67 | 100% |  | 2024-12-02 | 2024-12-06 | 5d | Boden | 40h | 40h |
| 70 | 1.4.3.5 | Estrich | manual | 2d | 2025-12-01 A | 2025-12-02 A | 69 | 100% |  | 2024-12-09 | 2024-12-10 | 2d | Estrich | 16h | 16h |
| 71 | 1.4.3.6 | Estrich Trocknung | manual | 8d | 2025-12-03 A | 2025-12-12 A | 70 | 100% |  | 2024-12-11 | 2024-12-20 | 8d | Estrich | 64h | 64h |
| 72 | 1.4.3.7 | Eckwand + 1. Seite | manual | 5d | 2025-12-29 A | 2026-01-02 A | 71FS+10d | 100% |  | 2025-01-06 | 2025-01-10 | 5d | Trockenbau | 40h | 40h |
| 73 | 1.4.3.8 | Leitung Wand | manual | 5d | 2026-01-05 A | 2026-01-09 A | 72 | 100% |  | 2025-01-13 | 2025-01-17 | 5d | Elektro - Fa. Elektro Blitz | 40h | 40h |
| 74 | 1.4.3.9 | 2. Seite + Q3 | manual | 5d | 2026-01-12 A | 2026-01-16 | 73 | 80% | 1d | 2025-01-20 | 2025-01-24 | 5d | Trockenbau | 40h | 32h |
| 75 | 1.4.3.10 | 1. Anstrich | manual | 5d | 2026-01-19 | 2026-01-23 | 74 |  |  | 2025-01-27 | 2025-01-31 | 5d | Maler | 40h |  |
| 76 | 1.4.3.11 | Systemtrennwände | manual | 10d | 2026-01-26 | 2026-02-06 | 75 |  |  | 2025-02-03 | 2025-02-14 | 10d | Systemtrennwände | 80h |  |
| 77 | 1.4.3.12 | Bodenbelag | manual | 5d | 2026-02-09 | 2026-02-13 | 76 |  |  | 2025-02-17 | 2025-02-21 | 5d | Teppich | 40h |  |
| 78 | 1.4.3.13 | Bodentanks | manual | 5d | 2026-02-16 | 2026-02-20 | 77 |  |  | 2025-02-24 | 2025-02-28 | 5d | Teppich | 40h |  |
| 79 | 1.4.3.14 | Türen | manual | 5d | 2026-02-16 | 2026-02-20 | 78SS |  |  | 2025-02-24 | 2025-02-28 | 5d | Türen | 40h |  |
| 80 | 1.4.3.15 | Heizkörper | manual | 5d | 2026-02-23 | 2026-02-27 | 78, 79 |  |  | 2025-03-03 | 2025-03-07 | 5d | Heizungsbauer | 40h |  |
| 81 | 1.4.3.16 | Feininstallation HLS | manual | 10d | 2026-02-23 | 2026-03-06 | 80SS |  |  | 2025-03-03 | 2025-03-14 | 10d | HLS | 80h |  |
| 82 | 1.4.3.17 | Schließzylinder | manual | 1d | 2026-03-09 | 2026-03-09 | 81 |  |  | 2025-03-17 | 2025-03-17 | 1d | Bauherr | 8h |  |
| 83 | 1.4.3.18 | Schalter + Lampen | manual | 5d | 2026-03-09 | 2026-03-13 | 82SS |  |  | 2025-03-17 | 2025-03-21 | 5d | Elektro - Fa. Elektro Blitz | 40h |  |
| 84 | 1.4.3.19 | 2. Anstrich | manual | 5d | 2026-03-16 | 2026-03-20 | 83 |  |  | 2025-03-24 | 2025-03-28 | 5d | Maler | 40h |  |
| 85 | 1.4.3.20 | WC-Gegenstände | manual | 5d | 2026-03-23 | 2026-03-27 | 82, 84 |  |  | 2025-03-31 | 2025-04-04 | 5d | Sanitär - Fa. Rohr Frei | 40h |  |
| 86 | 1.4.3.21 | Endreinigung | manual | 5d | 2026-03-30 | 2026-04-03 | 85 |  |  | 2025-04-07 | 2025-04-11 | 5d | Reinigung - Fa. Gebäudereinigung Blitzblank | 40h |  |
| 87 | 1.4.3.22 | Ausbau fertig | milestone, manual | 0d | 2026-04-06 | 2026-04-06 | 41, 86, 64 |  |  | 2025-04-14 | 2025-04-14 | 0d | Meilensteine |  |  |

| ID | WBS | Task | Type | Duration | Start | Finish | Predecessors | Complete | Remaining | Baseline start | Baseline finish | Baseline duration | Resources | Work | Actual work |
| --- | --- | --- | --- | --- | --- | --- | --- | --- | --- | --- | --- | --- | --- | --- | --- |
| 88 | 1.4.4 | **Kindergarten EG** |  | 1d | 2025-11-03 A | 2025-11-03 |  | 42% | 0.58d | 2024-11-25 | 2025-04-14 | 0d |  | 808h | 336h |
| 89 | 1.4.4.1 | Innenputz | manual | 5d | 2025-11-03 A | 2025-11-07 A |  | 100% |  | 2024-11-25 | 2024-11-29 | 5d | Innenputz | 40h | 40h |
| 90 | 1.4.4.2 | Rohrleitungen HLS | manual | 10d | 2025-11-10 A | 2025-11-21 A |  | 100% |  | 2024-12-02 | 2024-12-13 | 10d | HLS | 80h | 80h |
| 91 | 1.4.4.3 | Estrich | manual | 2d | 2025-11-24 A | 2025-11-25 A |  | 100% |  | 2024-12-16 | 2024-12-17 | 2d | Estrich | 16h | 16h |
| 92 | 1.4.4.4 | Estrich Trocknung | manual | 8d | 2025-11-26 A | 2025-12-05 A |  | 100% |  | 2024-12-18 | 2024-12-27 | 8d | Estrich | 64h | 64h |
| 93 | 1.4.4.5 | 1. Seite | manual | 5d | 2025-12-22 A | 2025-12-26 A |  | 100% |  | 2025-01-13 | 2025-01-17 | 5d | Trockenbau | 40h | 40h |
| 94 | 1.4.4.6 | Leitung Wand | manual | 5d | 2025-12-29 A | 2026-01-02 A |  | 100% |  | 2025-01-20 | 2025-01-24 | 5d | Elektro - Fa. Elektro Blitz | 40h | 40h |
| 95 | 1.4.4.7 | 2. Seite + Q3 | manual | 5d | 2026-01-05 A | 2026-01-09 |  | 60% | 2d | 2025-01-27 | 2025-01-31 | 5d | Trockenbau | 40h | 24h |
| 96 | 1.4.4.8 | 1. Anstrich | manual | 5d | 2026-01-12 A | 2026-01-16 |  | 80% | 1d | 2025-02-03 | 2025-02-07 | 5d | Maler | 40h | 32h |
| 97 | 1.4.4.9 | Fliesen | manual | 5d | 2026-01-19 | 2026-01-23 |  |  |  | 2025-02-10 | 2025-02-14 | 5d | Boden | 40h |  |
| 98 | 1.4.4.10 | Küchenbauer | manual | 10d | 2026-01-26 | 2026-02-06 |  |  |  | 2025-02-17 | 2025-02-28 | 10d | Küchenbauer | 80h |  |
| 99 | 1.4.4.11 | Bodenbelag | manual | 5d | 2026-02-09 | 2026-02-13 |  |  |  | 2025-03-03 | 2025-03-07 | 5d | Teppich | 40h |  |
| 100 | 1.4.4.12 | Türen | manual | 5d | 2026-02-09 | 2026-02-13 |  |  |  | 2025-03-03 | 2025-03-07 | 5d | Türen | 40h |  |
| 101 | 1.4.4.13 | Heizkörper | manual | 5d | 2026-02-16 | 2026-02-20 |  |  |  | 2025-03-10 | 2025-03-14 | 5d | Heizungsbauer | 40h |  |
| 102 | 1.4.4.14 | Feininstallation HLS | manual | 5d | 2026-02-16 | 2026-02-20 |  |  |  | 2025-03-10 | 2025-03-14 | 5d | HLS | 40h |  |
| 103 | 1.4.4.15 | Schließzylinder | manual | 1d | 2026-02-23 | 2026-02-23 |  |  |  | 2025-03-17 | 2025-03-17 | 1d | Bauherr | 8h |  |
| 104 | 1.4.4.16 | Schalter + Lampen | manual | 5d | 2026-02-23 | 2026-02-27 |  |  |  | 2025-03-17 | 2025-03-21 | 5d | Elektro - Fa. Elektro Blitz | 40h |  |
| 105 | 1.4.4.17 | 2. Anstrich | manual | 5d | 2026-03-02 | 2026-03-06 |  |  |  | 2025-03-24 | 2025-03-28 | 5d | Maler | 40h |  |
| 106 | 1.4.4.18 | WC-Gegenstände | manual | 5d | 2026-03-09 | 2026-03-13 |  |  |  | 2025-03-31 | 2025-04-04 | 5d | Sanitär - Fa. Rohr Frei | 40h |  |
| 107 | 1.4.4.19 | Endreinigung | manual | 5d | 2026-03-16 | 2026-03-20 |  |  |  | 2025-04-07 | 2025-04-11 | 5d | Reinigung - Fa. Gebäudereinigung Blitzblank | 40h |  |
| 108 | 1.4.4.20 | Übergabe | milestone, manual | 0d | 2026-03-23 | 2026-03-23 |  |  |  | 2025-04-14 | 2025-04-14 | 0d | Meilensteine |  |  |
| 109 | 1.4.5 | **Mängelbeseitigung** |  | 1d | 2026-05-25 | 2026-05-25 |  |  |  | 2025-06-02 | 2025-07-21 | 0d |  | 280h |  |
| 110 | 1.4.5.1 | Mängelaufnahme | manual | 5d | 2026-05-25 | 2026-05-29 | 116FS+5d |  |  | 2025-06-02 | 2025-06-06 | 5d | Mängelmanagement | 40h |  |
| 111 | 1.4.5.2 | Dokumentation | manual | 5d | 2026-06-01 | 2026-06-05 | 110 |  |  | 2025-06-09 | 2025-06-13 | 5d | Mängelmanagement | 40h |  |
| 112 | 1.4.5.3 | Mängelabarbeitung | manual | 20d | 2026-06-08 | 2026-07-03 | 111 |  |  | 2025-06-16 | 2025-07-11 | 20d | Mängelmanagement | 160h |  |
| 113 | 1.4.5.4 | Nachkontrolle | manual | 5d | 2026-07-06 | 2026-07-10 | 112 |  |  | 2025-07-14 | 2025-07-18 | 5d | Mängelmanagement | 40h |  |
| 114 | 1.4.5.5 | Mängelfrei | milestone, manual | 0d | 2026-07-13 | 2026-07-13 | 113 |  |  | 2025-07-21 | 2025-07-21 | 0d | Meilensteine |  |  |

| ID | WBS | Task | Type | Duration | Start | Finish | Predecessors | Baseline start | Baseline finish | Baseline duration | Resources | Work |
| --- | --- | --- | --- | --- | --- | --- | --- | --- | --- | --- | --- | --- |
| 115 | 1.5 | **Inbetriebnahme** |  | 1d | 2026-04-20 | 2026-04-20 |  | 2025-04-28 | 2025-07-28 | 0d |  | 160h |
| 116 | 1.5.1 | Inbetriebnahme TGA | manual | 20d | 2026-04-20 | 2026-05-15 | 86, 87FS+10d | 2025-04-28 | 2025-05-23 | 20d | TGA | 160h |
| 117 | 1.5.2 | Übergabe an Bauherr | milestone, manual | 0d | 2026-07-20 | 2026-07-20 | 114FS+5d | 2025-07-28 | 2025-07-28 | 0d | Meilensteine |  |
| 118 | 2 | **Gebäude 2** |  | 1d | 2025-04-28 | 2025-04-28 |  |  |  |  |  |  |
| 119 | 2.1 | Ausbau | manual | 1d | 2025-04-28 | 2025-04-28 |  |  |  |  |  |  |
